# ΑΣΤ_ΟΔΟΠ

Schedule from MS Project, 2002-01-01 to 2004-06-30, 24 hours a day.
NAMA SA

## Calendars

- 24 Hours: Mon-Sun 00:00-24:00.

## Resources

| Resource |
| --- |
| Εργοδότης |
| Προιστάμενη Αρχή |
| Διευθύνουσα Υπηρεσία |
| Γενικός Μελετητής |
| Αλλοι τοπικοί φορείς |
| Μελετητές |
| Γεωλόγος |
| Δνση Χωροταξίας ΥΠΕΧΩΔΕ |
| ΓΓ Περίφέρειας |
| Δνση Χωροταξίας (Κεντρική ή Περιφερειακή) |
| Υπουργείο Γεωργίας |
| ΥΠΠΟ |
| ΥΠΕΧΩΔΕ/Περιβάλλον |
| Τοπογράφος |
| Γεωτεχνικός |
| Κυκλοφοριολόγος |
| Μελετητης Περιβαλλοντολόγος |
| Δνση Περιβαλλοντικού Σχεδιασμού / ΥΠΕΧΩΔΕ |
| Δνση Περιβαλλοντος και Χωροταξίας Γενικής Γραμματείας της Περιφέρειας |
| Νομαρχιακό Συμβούλιο |
| Ενδιαφερόμενο Κοινό |
| Εδαφοτεχνικός Μελετητης |
| Συγκοινωνιλόγος Μηχανικός |
| Κύριος του Έργου |
| Γενικός Μελετητής(Ειδικός Συγκοινωνιολόγος) |
| Μελετήτής Οικονομολόγος |
| Δνση Χωροταξίας ΥΠΕΧΩΔΕ ή ΓΓ Περίφέρειας |
| ΥΠΕΧΩΔΕ |
| Ηλεκτρολόγος-Μηχανολόγος |
| ΓΕΜ |
| Συναρμόδιοι |
| ΕΥΠΕ ή ΔΙΠΕΧΩ ΓΓ Περιφέρειας |
| ΕΥΠΕ |
| Συναρμόδιοι Υπουργοί |
| Συναρμόδια Υπουργεία |

## Schedule

| ID | WBS | Task | Type | Duration | Start | Finish | Predecessors | Baseline start | Baseline finish | Baseline duration | Total slack | Free slack | Resources | Work | Text1 |
| --- | --- | --- | --- | --- | --- | --- | --- | --- | --- | --- | --- | --- | --- | --- | --- |
| 1 | 1 | **Διαδικασία επιλογής μελετητή** |  | 180d | 2002-01-01 | 2002-06-30 |  | 2002-01-11 | 2002-01-11 | 0.33d? | 0d |  | Εργοδότης | 10440h | 6Μ |
| 2 | 1.1 | Δημοσίευση Προκήρυξης Μελέτης |  | 45d | 2002-01-01 | 2002-02-15 |  | 2002-01-11 | 2002-01-11 | 0.33d? | 0d |  | Εργοδότης | 1080h | 1.5Μ |
| 3 | 1.2 | Αξιολόγηση Υποψήφιων Mελετητών |  | 30d | 2002-02-15 | 2002-03-17 | 2 | 2002-02-10 | 2002-03-12 | 30d | 0d |  | Εργοδότης | 720h | 1Μ |
| 4 | 1.3 | Επιλογή Μελετητή |  | 15d | 2002-03-17 | 2002-04-01 | 3 | 2002-03-12 | 2002-03-27 | 15d | 0d |  | Εργοδότης | 360h | 0.5Μ |
| 5 | 1.4 | Κοινοποίηση Aπόφασης Aνάθεσης |  | 15d | 2002-04-01 | 2002-04-16 | 4 | 2002-03-27 | 2002-04-11 | 15d | 0d |  | Εργοδότης | 360h | 0.5Μ |
| 6 | 1.5 | Διαδικασία Eνστάσεων |  | 75d | 2002-04-16 | 2002-06-30 | 5 | 2002-04-11 | 2002-06-30 | 80d | 0d |  | Εργοδότης; ΓΕΜ | 3600h | 2.5Μ |
| 7 | 1.6 | Ανάθεση Μελέτης | milestone | 0d | 2002-06-30 | 2002-06-30 | 6 | 2002-06-30 | 2002-06-30 | 0d? | 0d |  | Εργοδότης |  | 0Μ |
| 8 | 2 | Κατάρτιση Σύμβασης - Υπογραφή Σύμβασης - Εγκατάσταση Αναδόχου |  | 31d | 2002-06-30 | 2002-07-31 | 7 | 2002-06-30 | 2002-07-31 | 31d | 0d |  | Εργοδότης; Προιστάμενη Αρχή; Διευθύνουσα Υπηρεσία; Γενικός Μελετητής | 2976h | 1Μ |
| 9 | 3 | Επίβλεψη Μελέτης |  | 700d | 2002-07-31 | 2004-06-30 | 8 | 2002-07-31 | 2004-09-30 | 792d | 0d |  | Διευθύνουσα Υπηρεσία; Γενικός Μελετητής | 33600h | 23M |
| 10 | 4 | Εποπτεία Μελέτης |  | 700d | 2002-07-31 | 2004-06-30 | 9SS | 2002-07-31 | 2004-09-30 | 792d | 0d |  | Προιστάμενη Αρχή; Γενικός Μελετητής | 33600h | 23M |
| 11 | 5 | **Στάδιο Ι: Αναγνωριστική μελέτη έργου / Προμελέτη Περιβαλλοντικών Επιπτώσεων** |  | 167d | 2002-07-31 | 2003-01-14 | 10SS | 2002-07-31 | 2002-12-17 | 139d | 0d |  |  | 17208h | 5.5Μ |
| 12 | 5.1 | Κυκλοφοριακή μελέτη / Θέσεις Kόμβων |  | 61d | 2002-07-31 | 2002-09-30 |  | 2002-07-31 | 2002-09-29 | 2mo | 0d |  | Εργοδότης; Γενικός Μελετητής(Ειδικός Συγκοινωνιολόγος) | 2928h | 2Μ |
| 13 | 5.2 | Εύρεση θεσμοθετημένου ή Πρόγραμμα Πολεοδομίας Περιβάλλοντος |  | 61d | 2002-07-31 | 2002-09-30 | 12SS | 2002-07-31 | 2002-09-29 | 60d | 0d |  | Γενικός Μελετητής; Διευθύνουσα Υπηρεσία | 2928h | 2Μ |
| 14 | 5.3 | Συλλογή Στοιχείων από Οργανισμούς Κοινής Ωφελείας |  | 61d | 2002-07-31 | 2002-09-30 | 13FS-61d | 2002-07-31 | 2002-09-30 | 61d | 0d |  | Γενικός Μελετητής; Διευθύνουσα Υπηρεσία | 2928h | 2Μ |
| 15 | 5.4 | Εκτέλεση Tοπογραφικών Eργασιών |  | 61d | 2002-07-31 | 2002-09-30 | 14FS-61d | 2002-07-31 | 2002-09-30 | 61d | 0d |  | Διευθύνουσα Υπηρεσία; Γενικός Μελετητής | 2928h | 2Μ |
| 16 | 5.5 | Προκαταρκτική Μελέτη Κυκλοφοριακού Έργου |  | 107d | 2002-08-31 | 2002-12-16 | 15FS-30d, 12FS-30d | 2002-08-31 | 2002-12-17 | 108d | 0d |  | Διευθύνουσα Υπηρεσία; Γενικός Μελετητής | 5136h | 3.5Μ |
| 17 | 5.6 | Προκαταρκτική Επεξεργασία Tεχνικών Εργων |  | 77d | 2002-09-30 | 2002-12-16 | 16SS+30d | 2002-09-30 | 2002-12-17 | 78d | 0d |  |  |  | 2.5Μ |
| 18 | 5.7 | Εκπόνηση Προμελέτης Περιβαλλοντικών Επιπτώσεων - Π.Π.Ε. (Φ. Π. Χ.) |  | 31d | 2002-11-15 | 2002-12-16 | 17SS+46d | 2002-11-15 | 2002-12-16 | 31d | 0d |  |  |  | 1Μ |
| 19 | 5.8 | **Διαδικασία Έκδοσης Προκαταρκτικής Περιβαλλοντικής Εκτίμησης και Αξιολόγησης (Π.Χ.)** |  | 29d | 2002-12-16 | 2003-01-14 | 18 | 2002-12-17 | 2003-01-16 | 30d | 0d |  |  | 360h | 1Μ |
| 20 | 5.8.1 | Παραλαβή Π.Π.Ε. (Φ.Π.Χ.) - Έλεγχος - Υποβολή |  | 7d | 2002-12-16 | 2002-12-23 |  | 2002-12-17 | 2002-12-20 | 3d | 0d |  | Διευθύνουσα Υπηρεσία | 168h | 0.25Μ |
| 21 | 5.8.2 | Παραλαβή Π.Π.Ε (Φ.Π.Χ) - Γνωμοδοτήσεις Συναρμοδιών |  | 15d | 2002-12-23 | 2003-01-07 | 20 | 2002-12-20 | 2002-12-23 | 3d | 0d |  | Συναρμόδιοι; ΕΥΠΕ ή ΔΙΠΕΧΩ ΓΓ Περιφέρειας | 160h | 0.5Μ |
| 22 | 5.8.3 | Έκδοση Προκαταρκτικής Περιβαλλοντικής Εκτίμησης και Αξιολόγησης (Π.Χ.) |  | 7d | 2003-01-07 | 2003-01-14 | 21 | 2003-01-10 | 2003-01-16 | 6d | 0d |  | ΕΥΠΕ ή ΔΙΠΕΧΩ ΓΓ Περιφέρειας | 32h | 0.25Μ |
| 23 | 6 | Έγκριση Σταδίου Ι |  | 29d | 2003-01-14 | 2003-02-12 | 22 | 2003-01-16 | 2003-02-15 | 30d | 0d |  | Εργοδότης | 696h | 1Μ |
| 24 | 7 | **ΣΤΑΔΙΟ ΙΙ: Προμελέτες Έργων / Μελέτη Περιβαλλοντικών Επιπτώσεων** |  | 275.38d | 2003-02-12 | 2003-11-14 | 23 | 2003-02-15 | 2003-10-31 | 258d | 0d |  |  | 42176h | 8.5Μ |
| 25 | 7.1 | Εντολή Έναρξης Σταδίου ΙΙ | milestone | 0d | 2003-02-12 | 2003-02-12 |  | 2003-02-15 | 2003-02-15 | 0d? | 0d |  | Εργοδότης |  | 0Μ |
| 26 | 7.2 | Συμπλήρωση Τοπογραφικών Υποβάθρων |  | 77d | 2003-02-12 | 2003-04-30 | 25 | 2003-02-15 | 2003-05-01 | 75d | 0d |  | Διευθύνουσα Υπηρεσία; Γενικός Μελετητής; Τοπογράφος | 5544h | 2.5Μ |
| 27 | 7.3 | Προμελέτη Κυκλοφοριακού Έργου / Κόμβων / Παράπλευρων Έργων |  | 138d | 2003-02-12 | 2003-06-30 | 26SS | 2003-02-15 | 2003-06-30 | 135d | 0d |  | Διευθύνουσα Υπηρεσία; Γενικός Μελετητής; Κυκλοφοριολόγος | 9936h | 4.5Μ |
| 28 | 7.4 | Προμελέτη Αποχέτευσης Αποστράγγισης |  | 91d | 2003-03-31 | 2003-06-30 | 27FS-91d | 2003-04-01 | 2003-06-30 | 90d | 0d |  | Γενικός Μελετητής; Διευθύνουσα Υπηρεσία | 4368h | 3Μ |
| 29 | 7.5 | Οριστική Γεωλογική Μελέτη |  | 91d | 2003-03-31 | 2003-06-30 | 28SS | 2003-04-01 | 2003-06-30 | 90d | 0d |  | Διευθύνουσα Υπηρεσία; Γενικός Μελετητής; Γεωλόγος; Γεωτεχνικός | 8736h | 3Μ |
| 30 | 7.6 | Προμελέτη Τεχνικών Έργων |  | 91d | 2003-03-31 | 2003-06-30 | 29SS | 2003-04-01 | 2003-06-30 | 90d | 0d |  | Διευθύνουσα Υπηρεσία; Γενικός Μελετητής | 4368h | 3Μ |
| 31 | 7.7 | Εκπόνηση Μελέτης Περιβαλλοντικών Επιπτώσεων - Υποβολή |  | 91d | 2003-03-31 | 2003-06-30 | 30SS | 2003-04-01 | 2003-06-30 | 90d | 243d | 0d | Διευθύνουσα Υπηρεσία; Γενικός Μελετητής; Μελετητης Περιβαλλοντολόγος | 6552h | 3Μ |

| ID | WBS | Task | Type | Duration | Start | Finish | Predecessors | Baseline start | Baseline finish | Baseline duration | Total slack | Free slack | Resources | Work | Text1 |
| --- | --- | --- | --- | --- | --- | --- | --- | --- | --- | --- | --- | --- | --- | --- | --- |
| 32 | 7.8 | **Έγκριση Μελέτης Περιβαλλοντικών Επιπτώσεων** |  | 137.38d | 2003-06-30 | 2003-11-14 | 31 | 2003-06-30 | 2003-10-31 | 123d | 228.62d |  |  | 2672h | 4Μ |
| 33 | 7.8.1 | Παραλάβή ΜΠΕ-¨Ελεγχος-Υποβολή |  | 15d | 2003-06-30 | 2003-07-15 |  | 2003-06-30 | 2003-07-14 | 14d | 230d | 0d | Διευθύνουσα Υπηρεσία | 360h | 0.5Μ |
| 34 | 7.8.2 | Παραλαβή της ΜΠΕ-Έλεγχος-Διαβίβαση |  | 16d | 2003-07-15 | 2003-07-31 | 33 | 2003-07-14 | 2003-08-13 | 30d | 230d | 0d | ΕΥΠΕ ή ΔΙΠΕΧΩ ΓΓ Περιφέρειας | 96h | 0.5Μ |
| 35 | 7.8.3 | Παραλαβή της ΜΠΕ-Γνωμοδότηση-Διαβίβαση |  | 15d | 2003-07-30 | 2003-08-14 | 34SS+15d | 2003-07-29 | 2003-08-13 | 15d | 321d |  | Συναρμόδια Υπουργεία | 88h | 0.5Μ |
| 36 | 7.8.4 | Νομαρχιακό Συμβούλιο: Παραλαβή-Δημοσίευση Ανάρτηση ΜΠΕ |  | 15d | 2003-07-31 | 2003-08-15 | 34 | 2003-08-13 | 2003-09-12 | 30d | 230d | 0d | Νομαρχιακό Συμβούλιο | 360h | 0.5Μ |
| 37 | 7.8.5 | Διατύπωση Απόψεων - Αντιρρήσεων - Προτάσεων |  | 15d | 2003-08-15 | 2003-08-30 | 36 | 2003-08-28 | 2003-09-17 | 20d | 230d | 0d | Ενδιαφερόμενο Κοινό | 360h | 0.5Μ |
| 38 | 7.8.6 | Νομαρχιακό Συμβούλιο: Κριτική Άποψη Διαβίβαση |  | 16.38d | 2003-08-30 | 2003-09-15 | 37 | 2003-09-17 | 2003-10-02 | 15d | 228.62d | 0d | Νομαρχιακό Συμβούλιο | 360h | 0.5Μ |
| 39 | 7.8.7 | Σύνταξη Σχεδίου Απόφασης Έγκρισης περιβαλλοντικών όρων |  | 30d | 2003-09-15 | 2003-10-15 | 38 | 2003-10-02 | 2003-10-17 | 15d | 228.62d | 0d | ΕΥΠΕ ή ΔΙΠΕΧΩ ΓΓ Περιφέρειας | 160h | 1Μ |
| 40 | 7.8.8 | Υπογραφή Υπουργών η Γ.Γ. Περιφέρειας |  | 15d | 2003-10-15 | 2003-10-30 | 39 | 2003-10-17 | 2003-10-31 | 14d | 228.62d | 0d | ΥΠΕΧΩΔΕ; ΓΓ Περίφέρειας; Συναρμόδιοι Υπουργοί | 800h | 0.5Μ |
| 41 | 7.8.9 | Έκδοση Απόφασης Έγκρισης Περιβαλλοντικών Όρων |  | 15d | 2003-10-30 | 2003-11-14 | 40 | 2003-10-31 | 2003-10-31 | 15d | 228.62d |  | ΕΥΠΕ ή ΔΙΠΕΧΩ ΓΓ Περιφέρειας | 88h | 0.5Μ |
| 42 | 8 | ¨Εγκριση Σταδίου ΙΙ |  | 31d | 2003-06-30 | 2003-07-31 | 30 | 2003-10-01 | 2003-10-31 | 30d | 0d |  | Εργοδότης | 744h | 1Μ |
| 43 | 9 | **ΣΤΑΔΙΟ ΙΙΙ: Οριστικές Μελέτες Έργων** |  | 184d | 2003-07-31 | 2004-01-31 | 42 | 2003-10-31 | 2004-05-01 | 183d | 0d |  |  | 51360h | 6Μ |
| 44 | 9.1 | Εντολή Εναρξης Σταδίου ΙΙΙ | milestone | 0d | 2003-07-31 | 2003-07-31 |  | 2003-10-31 | 2003-10-31 | 0d? | 0d |  | Εργοδότης |  | 0Μ |
| 45 | 9.2 | Οριστική Μελέτη Κυκλοφοριακού Έργου / Κόμβων/ Παράπλευρων Έργων |  | 184d | 2003-07-31 | 2004-01-31 | 44 | 2003-10-31 | 2004-05-01 | 183d | 0d |  | Διευθύνουσα Υπηρεσία; Γενικός Μελετητής | 8832h | 6Μ |
| 46 | 9.3 | Οριστική Μελέτη Αποχέτευσης - Αποστράγγισης |  | 123d | 2003-09-30 | 2004-01-31 | 45SS+61d | 2003-12-31 | 2004-04-29 | 120d | 0d |  | Διευθύνουσα Υπηρεσία; Γενικός Μελετητής | 5904h | 4Μ |
| 47 | 9.4 | Γεωτεχνικά Οδού και Τεχνικών Έργων |  | 122d | 2003-07-31 | 2003-11-30 | 44 | 2003-10-31 | 2004-03-01 | 122d | 62d |  | Διευθύνουσα Υπηρεσία; Εδαφοτεχνικός Μελετητης | 5856h | 4Μ |
| 48 | 9.5 | Μελέτη Σήμανσης/ Ασφάλισης |  | 122d | 2003-07-31 | 2003-11-30 | 44 | 2003-10-31 | 2004-02-28 | 120d | 1d | 0d | Διευθύνουσα Υπηρεσία; Συγκοινωνιλόγος Μηχανικός | 5856h | 4Μ |
| 49 | 9.6 | Εξοπλισμός Οδού |  | 122d | 2003-09-30 | 2004-01-30 | 48SS+61d | 2003-12-31 | 2004-04-29 | 120d | 1d |  | Διευθύνουσα Υπηρεσία; Γενικός Μελετητής; Ηλεκτρολόγος-Μηχανολόγος | 8784h | 4Μ |
| 50 | 9.7 | Μελέτη Σηματοδότησης |  | 122d | 2003-09-30 | 2004-01-30 | 45SS+61d | 2003-12-31 | 2004-04-29 | 120d | 1d |  | Διευθύνουσα Υπηρεσία; Γενικός Μελετητής; Κυκλοφοριολόγος | 8784h | 4Μ |
| 51 | 9.8 | Οριστική Μελέτη Τεχνικών Εργών |  | 153d | 2003-08-30 | 2004-01-30 | 44FS+30d | 2003-11-30 | 2004-04-30 | 152d | 1d |  | Διευθύνουσα Υπηρεσία; Γενικός Μελετητής | 7344h | 5Μ |
| 52 | 10 | Έγκριση Σταδίου ΙΙΙ |  | 29d | 2004-01-31 | 2004-02-29 | 43 | 2004-05-01 | 2004-06-01 | 31d | 0d |  | Εργοδότης | 696h | 1Μ |
| 53 | 11 | **ΣΤΑΔΙΟ V: Λοιπές Μελέτες** |  | 700d | 2002-07-31 | 2004-06-30 |  | 2004-01-01 | 2004-07-01 | 182d | 0d |  |  | 54816h | 6Μ |
| 54 | 11.1 | Κτηματολόγιο |  | 700d | 2002-07-31 | 2004-06-30 | 15SS | 2004-01-01 | 2004-06-30 | 181d | 0d |  | Διευθύνουσα Υπηρεσία; Γενικός Μελετητής; Τοπογράφος | 50400h | 4Μ |
| 55 | 11.2 | Μελέτες Εφαρμογής |  | 92d | 2004-02-29 | 2004-05-31 | 52 | 2004-03-31 | 2004-07-01 | 92d | 0d |  | Διευθύνουσα Υπηρεσία; Γενικός Μελετητής | 4416h | 3Μ |
| 56 | 12 | Έγκριση Σταδίου V |  | 30d | 2004-05-31 | 2004-06-30 | 55 | 2004-07-01 | 2004-08-01 | 31d | 0d |  | Εργοδότης | 720h | 1Μ |
| 57 | 13 | Απαλλοτριώσεις |  | 700d | 2002-07-31 | 2004-06-30 | 54SS | 2004-01-01 | 2004-07-31 | 212d | 0d |  |  |  | 7Μ |
| 58 | 14 | Σύνταξη Τευχών Δημοπράτησης |  | 61d | 2004-04-30 | 2004-06-30 | 52FS+61d | 2004-06-01 | 2004-07-30 | 59d | 0d |  | Διευθύνουσα Υπηρεσία; Γενικός Μελετητής | 2928h | 2Μ |
