# ΑΣΤ_ΟΔΟΠ

Schedule from MS Project, 2002-01-01 to 2003-11-30, 24 hours a day.
NAMA SA

## Calendars

- 24 Hours: Mon-Sun 00:00-24:00.

## Resources

| Resource |
| --- |
| Εργοδότης |
| Προιστάμενη Αρχή |
| Διευθύνουσα Υπηρεσία |
| Γενικός Μελετητής |
| Αλλοι τοπικοί φορείς |
| Μελετητές |
| Γεωλόγος |
| Δνση Χωροταξίας ΥΠΕΧΩΔΕ |
| ΓΓ Περίφέρειας |
| Δνση Χωροταξίας (Κεντρική ή Περιφερειακή) |
| Υπουργείο Γεωργίας |
| ΥΠΠΟ |
| ΥΠΕΧΩΔΕ/Περιβάλλον |
| Τοπογράφος |
| Γεωτεχνικός |
| Κυκλοφοριολόγος |
| Μελετητης Περιβαλλοντολόγος |
| Δνση Περιβαλλοντικού Σχεδιασμού / ΥΠΕΧΩΔΕ |
| Δνση Περιβαλλοντος και Χωροταξίας Γενικής Γραμματείας της Περιφέρειας |
| Νομαρχιακό Συμβούλιο |
| Ενδιαφερόμενο Κοινό |
| Εδαφοτεχνικός Μελετητης |
| Συγκοινωνιλόγος Μηχανικός |
| Κύριος του Έργου |
| Γενικός Μελετητής(Ειδικός Συγκοινωνιολόγος) |
| Μελετήτής Οικονομολόγος |
| Δνση Χωροταξίας ΥΠΕΧΩΔΕ ή ΓΓ Περίφέρειας |
| ΥΠΕΧΩΔΕ |
| Ηλεκτρολόγος-Μηχανολόγος |
| ΓΕΜ |
| Συναρμόδιοι |
| ΕΥΠΕ ή ΔΙΠΕΧΩ ΓΓ Περιφέρειας |
| ΕΥΠΕ |
| Συναρμόδιοι Υπουργοί |
| Συναρμόδια Υπουργεία |

## Schedule

| ID | WBS | Task | Type | Duration | Start | Finish | Predecessors | Baseline start | Baseline finish | Baseline duration | Total slack | Free slack | Resources | Work | Text1 |
| --- | --- | --- | --- | --- | --- | --- | --- | --- | --- | --- | --- | --- | --- | --- | --- |
| 1 | 1 | **Διαδικασία επιλογής μελετητή** |  | 180d | 2002-01-01 | 2002-06-30 |  | 2002-01-11 | 2002-01-11 | 0.33d? | 0d |  | Εργοδότης | 10440h | 6Μ |
| 2 | 1.1 | Δημοσίευση Προκήρυξης Μελέτης |  | 45d | 2002-01-01 | 2002-02-15 |  | 2002-01-11 | 2002-01-11 | 0.33d? | 0d |  | Εργοδότης | 1080h | 1.5Μ |
| 3 | 1.2 | Αξιολόγηση Υποψήφιων Mελετητών |  | 30d | 2002-02-15 | 2002-03-17 | 2 | 2002-02-10 | 2002-03-12 | 30d | 0d |  | Εργοδότης | 720h | 1Μ |
| 4 | 1.3 | Επιλογή Μελετητή |  | 15d | 2002-03-17 | 2002-04-01 | 3 | 2002-03-12 | 2002-03-27 | 15d | 0d |  | Εργοδότης | 360h | 0.5Μ |
| 5 | 1.4 | Κοινοποίηση Aπόφασης Aνάθεσης |  | 15d | 2002-04-01 | 2002-04-16 | 4 | 2002-03-27 | 2002-04-11 | 15d | 0d |  | Εργοδότης | 360h | 0.5Μ |
| 6 | 1.5 | Διαδικασία Eνστάσεων |  | 75d | 2002-04-16 | 2002-06-30 | 5 | 2002-04-11 | 2002-06-30 | 80d | 0d |  | Εργοδότης; ΓΕΜ | 3600h | 2.5Μ |
| 7 | 1.6 | Ανάθεση Μελέτης | milestone | 0d | 2002-06-30 | 2002-06-30 | 6 | 2002-06-30 | 2002-06-30 | 0d? | 0d |  | Εργοδότης |  | 0Μ |
| 8 | 2 | Κατάρτιση Σύμβασης - Υπογραφή Σύμβασης - Εγκατάσταση Αναδόχου |  | 31d | 2002-06-30 | 2002-07-31 | 7 | 2002-06-30 | 2002-07-31 | 31d | 0d |  | Εργοδότης; Προιστάμενη Αρχή; Διευθύνουσα Υπηρεσία; Γενικός Μελετητής | 2976h | 1Μ |
| 9 | 3 | Επίβλεψη Μελέτης |  | 487d | 2002-07-31 | 2003-11-30 | 8 | 2002-07-31 | 2004-09-30 | 792d | 0d |  | Διευθύνουσα Υπηρεσία; Γενικός Μελετητής | 23376h | 23M |
| 10 | 4 | Εποπτεία Μελέτης |  | 487d | 2002-07-31 | 2003-11-30 | 9SS | 2002-07-31 | 2004-09-30 | 792d | 0d |  | Προιστάμενη Αρχή; Γενικός Μελετητής | 23376h | 23M |
| 11 | 5 | **ΣΤΑΔΙΟ Ι: Αναγνωριστική μελέτη έργου/Προμελέτη Περιβαλλοντικών Επιπτώσεων (Π.Χ.)** |  | 169d | 2002-07-31 | 2003-01-16 | 10SS | 2002-07-31 | 2002-12-17 | 139d | 0d |  |  | 17224h | 5.5Μ |
| 12 | 5.1 | Κυκλοφοριακή μελέτη / Θέσεις Kόμβων |  | 61d | 2002-07-31 | 2002-09-30 |  | 2002-07-31 | 2002-09-29 | 2mo | 0d |  | Εργοδότης; Γενικός Μελετητής(Ειδικός Συγκοινωνιολόγος) | 2928h | 2Μ |
| 13 | 5.2 | Εύρεση θεσμοθετημένου ή Πρόγραμμα Πολεοδομίας Περιβάλλοντος |  | 61d | 2002-07-31 | 2002-09-30 | 12SS | 2002-07-31 | 2002-09-29 | 60d | 0d |  | Γενικός Μελετητής; Διευθύνουσα Υπηρεσία | 2928h | 2Μ |
| 14 | 5.3 | Συλλογή στοιχείων από Οργανισμούς Κοινής Ωφελείας |  | 61d | 2002-07-31 | 2002-09-30 | 13FS-61d | 2002-07-31 | 2002-09-30 | 61d | 0d |  | Γενικός Μελετητής; Διευθύνουσα Υπηρεσία | 2928h | 2Μ |
| 15 | 5.4 | Εκτέλεση Tοπογραφικών Eργασιών |  | 61d | 2002-07-31 | 2002-09-30 | 14FS-61d | 2002-07-31 | 2002-09-30 | 61d | 0d |  | Διευθύνουσα Υπηρεσία; Γενικός Μελετητής | 2928h | 2Μ |
| 16 | 5.5 | Προκαταρκτική Μελέτη Κυκλοφοριακού Έργου |  | 107d | 2002-08-31 | 2002-12-16 | 15FS-30d, 12FS-30d | 2002-08-31 | 2002-12-17 | 108d | 0d |  | Διευθύνουσα Υπηρεσία; Γενικός Μελετητής | 5136h | 3.5Μ |
| 17 | 5.6 | Προκαταρκτική Επεξεργασία Tεχνικών Εργων |  | 77d | 2002-09-30 | 2002-12-16 | 16SS+30d | 2002-09-30 | 2002-12-17 | 78d | 0d |  |  |  | 2.5Μ |
| 18 | 5.7 | Εκπόνηση Προμελέτης Περιβαλλοντικών Επιπτώσεων-Π.Π.Ε. |  | 30d | 2002-11-16 | 2002-12-16 | 17FF |  |  |  | 0d |  |  |  | 1Μ |
| 19 | 5.8 | **Διαδικασία Έκδοσης Προκαταρκτικής Περιβαλλοντικής Αξιολόγησης (Π.Χ.)** |  | 31d | 2002-12-16 | 2003-01-16 | 18 | 2002-12-17 | 2003-01-16 | 30d | 0d |  |  | 376h | 1Μ |
| 20 | 5.8.1 | Παραλαβή Π.Π.Ε. (Φ.Π.Χ.) - Έλεγχος - Υποβολή |  | 7d | 2002-12-16 | 2002-12-23 |  | 2002-12-17 | 2002-12-20 | 3d | 0d |  | Διευθύνουσα Υπηρεσία | 168h | 0.25Μ |
| 21 | 5.8.2 | Παραλαβή Π.Π.Ε. (Φ.Π.Χ.) - Γνωμοδοτήσεις Συναρμοδιών |  | 16d | 2002-12-23 | 2003-01-08 | 20 | 2002-12-20 | 2002-12-23 | 3d | 0d |  | Συναρμόδιοι; ΕΥΠΕ ή ΔΙΠΕΧΩ ΓΓ Περιφέρειας | 160h | 0.5Μ |
| 22 | 5.8.3 | Έκδοση Προκαταρκτικής Περιβαλλοντικής Εκτίμησης και Αξιολόγησης (Π. Χ.) |  | 8d | 2003-01-08 | 2003-01-16 | 21 | 2003-01-10 | 2003-01-16 | 6d | 0d |  | ΕΥΠΕ ή ΔΙΠΕΧΩ ΓΓ Περιφέρειας | 48h | 0.25Μ |
| 23 | 6 | Έγκριση Σταδίου Ι |  | 29d | 2003-01-16 | 2003-02-14 | 22 | 2003-01-16 | 2003-02-15 | 30d | 0d |  | Εργοδότης | 696h | 1Μ |
| 24 | 7 | **ΣΤΑΔΙΟ ΙΙ: Προμελέτες Έργων / Μελέτη Περιβαλλοντικών Επιπτώσεων** |  | 273d | 2003-02-14 | 2003-11-14 | 23 | 2003-02-15 | 2003-10-31 | 258d | 0d |  |  | 41840h | 8.5Μ |
| 25 | 7.1 | Εντολή Έναρξης Σταδίου ΙΙ | milestone | 0d | 2003-02-14 | 2003-02-14 |  | 2003-02-15 | 2003-02-15 | 0d? | 0d |  | Εργοδότης |  | 0Μ |
| 26 | 7.2 | Συμπλήρωση τοπογραφικών υποβάθρων |  | 75d | 2003-02-14 | 2003-04-30 | 25 | 2003-02-15 | 2003-05-01 | 75d | 0d |  | Διευθύνουσα Υπηρεσία; Γενικός Μελετητής; Τοπογράφος | 5400h | 2.5Μ |
| 27 | 7.3 | Προμελέτη κυκλοφοριακού έργου / Κόμβων / Παράπλευρων Έργων |  | 135d | 2003-02-14 | 2003-06-29 | 26SS | 2003-02-15 | 2003-06-30 | 135d | 0d |  | Διευθύνουσα Υπηρεσία; Γενικός Μελετητής; Κυκλοφοριολόγος | 9720h | 4.5Μ |
| 28 | 7.4 | Προμελέτη Αποχέτευσης Αποστράγγισης |  | 91d | 2003-03-31 | 2003-06-30 | 27FS-90d | 2003-04-01 | 2003-06-30 | 90d | 0d |  | Γενικός Μελετητής; Διευθύνουσα Υπηρεσία | 4368h | 3Μ |
| 29 | 7.5 | Οριστική Γεωλογική Μελέτη |  | 91d | 2003-03-31 | 2003-06-30 | 28SS | 2003-04-01 | 2003-06-30 | 90d | 0d |  | Διευθύνουσα Υπηρεσία; Γενικός Μελετητής; Γεωλόγος; Γεωτεχνικός | 8736h | 3Μ |
| 30 | 7.6 | Προμελέτη Τεχνικών Έργων |  | 91d | 2003-03-31 | 2003-06-30 | 29SS | 2003-04-01 | 2003-06-30 | 90d | 0d |  | Διευθύνουσα Υπηρεσία; Γενικός Μελετητής | 4368h | 3Μ |
| 31 | 7.7 | Εκπόνηση Μελέτης Περιβαλλοντικών Επιπτώσεων - Υποβολή |  | 91d | 2003-03-31 | 2003-06-30 | 30SS | 2003-04-01 | 2003-06-30 | 90d | 30d | 0d | Διευθύνουσα Υπηρεσία; Γενικός Μελετητής; Μελετητης Περιβαλλοντολόγος | 6552h | 3Μ |

| ID | WBS | Task | Duration | Start | Finish | Predecessors | Baseline start | Baseline finish | Baseline duration | Total slack | Free slack | Resources | Work | Text1 |
| --- | --- | --- | --- | --- | --- | --- | --- | --- | --- | --- | --- | --- | --- | --- |
| 32 | 7.8 | **Έγκριση Μελέτης Περιβαλλοντικών Επιπτώσεων** | 137d | 2003-06-30 | 2003-11-14 | 31 | 2003-06-30 | 2003-10-31 | 123d | 16d |  |  | 2696h | 4.5Μ |
| 33 | 7.8.1 | Παραλάβή ΜΠΕ-¨Ελεγχος-Υποβολή | 16d | 2003-06-30 | 2003-07-16 |  | 2003-06-30 | 2003-07-14 | 14d | 30d | 0d | Διευθύνουσα Υπηρεσία | 384h | 0.5Μ |
| 34 | 7.8.2 | Παραλαβή της ΜΠΕ-Έλεγχος-Διαβίβαση | 15d | 2003-07-16 | 2003-07-31 | 33 | 2003-07-14 | 2003-08-13 | 30d | 30d | 0d | ΕΥΠΕ ή ΔΙΠΕΧΩ ΓΓ Περιφέρειας | 88h | 0.5Μ |
| 35 | 7.8.3 | Παραλαβή της ΜΠΕ-Γνωμοδότηση-Διαβίβαση | 15d | 2003-07-31 | 2003-08-15 | 34SS+15d | 2003-07-29 | 2003-08-13 | 15d | 106d |  | Συναρμόδια Υπουργεία | 88h | 0.5Μ |
| 36 | 7.8.4 | Νομαρχιακό Συμβούλιο: Παραλαβή-Δημοσίευση Ανάρτηση ΜΠΕ | 15d | 2003-07-31 | 2003-08-15 | 34 | 2003-08-13 | 2003-09-12 | 30d | 30d | 0d | Νομαρχιακό Συμβούλιο | 360h | 0.5Μ |
| 37 | 7.8.5 | Διατύπωση απόψεων - Αντιρρήσεων - Προτάσεων | 15d | 2003-08-15 | 2003-08-30 | 36 | 2003-08-28 | 2003-09-17 | 20d | 17d | 0d | Ενδιαφερόμενο Κοινό | 360h | 0.5Μ |
| 38 | 7.8.6 | Νομαρχιακό Συμβούλιο: Κριτική Άποψη Διαβίβαση | 15d | 2003-08-30 | 2003-09-14 | 37 | 2003-09-17 | 2003-10-02 | 15d | 15d | 0d | Νομαρχιακό Συμβούλιο | 360h | 0.5Μ |
| 39 | 7.8.7 | Σύνταξη Σχεδίου Απόφασης Έγκρισης Περιβαλλοντικών Όρων | 31d | 2003-09-14 | 2003-10-15 | 38 | 2003-10-02 | 2003-10-17 | 15d | 15d | 0d | ΕΥΠΕ ή ΔΙΠΕΧΩ ΓΓ Περιφέρειας | 160h | 1Μ |
| 40 | 7.8.8 | Υπογραφή Υπουργών η Γ.Γ. Περιφέρειας | 15d | 2003-10-15 | 2003-10-30 | 39 | 2003-10-17 | 2003-10-31 | 14d | 15d | 0d | ΥΠΕΧΩΔΕ; ΓΓ Περίφέρειας; Συναρμόδιοι Υπουργοί | 808h | 0.5Μ |
| 41 | 7.8.9 | Έκδοση Απόφασης Εγκρισης Περιβαλλοντικών Όρων | 15d | 2003-10-30 | 2003-11-14 | 40 | 2003-10-31 | 2003-10-31 | 15d | 15d |  | ΕΥΠΕ ή ΔΙΠΕΧΩ ΓΓ Περιφέρειας | 88h | 0.5Μ |
| 42 | 8 | ¨Εγκριση Σταδίου ΙΙ | 31d | 2003-06-30 | 2003-07-31 | 30 | 2003-10-01 | 2003-10-31 | 30d | 0d |  | Εργοδότης | 744h | 1Μ |
| 43 | 9 | **ΣΤΑΔΙΟ III: Λοιπές Μελέτες** | 487d | 2002-07-31 | 2003-11-30 |  | 2004-01-01 | 2004-07-01 | 182d | 0d |  |  | 39480h | 6Μ |
| 44 | 9.1 | Κτηματολόγιο | 487d | 2002-07-31 | 2003-11-30 | 15SS | 2004-01-01 | 2004-06-30 | 181d | 0d |  | Διευθύνουσα Υπηρεσία; Γενικός Μελετητής; Τοπογράφος | 35064h | 4Μ |
| 45 | 9.2 | Μελέτες Εφαρμογής | 92d | 2003-07-31 | 2003-10-31 | 42 | 2004-03-31 | 2004-07-01 | 92d | 0d |  | Διευθύνουσα Υπηρεσία; Γενικός Μελετητής | 4416h | 3Μ |
| 46 | 10 | Εγκριση Σταδίου III | 30d | 2003-10-31 | 2003-11-30 | 45 | 2004-07-01 | 2004-08-01 | 31d | 0d |  | Εργοδότης | 720h | 1Μ |
| 47 | 11 | Απαλλοτριώσεις | 487d | 2002-07-31 | 2003-11-30 | 44SS | 2004-01-01 | 2004-07-31 | 212d | 0d |  |  |  | 7Μ |
| 48 | 12 | Σύνταξη Τευχών Δημοπράτησης | 61d | 2003-09-30 | 2003-11-30 | 42FS+61d | 2004-06-01 | 2004-07-30 | 59d | 0d |  | Διευθύνουσα Υπηρεσία; Γενικός Μελετητής | 2928h | 2Μ |
