# ΑΣΤ_ΟΔΟΠ (ΣΥΛ ΔΡΟΜΟΙ)ΤΕΛ

Schedule from MS Project, 2002-01-01 to 2003-09-30, 24 hours a day.
NAMA SA

## Calendars

- 24 Hours: Mon-Sun 00:00-24:00.

## Resources

| Resource |
| --- |
| Εργοδότης |
| Προιστάμενη Αρχή |
| Διευθύνουσα Υπηρεσία |
| Γεν. Μελετητής |
| Αλλοι τοπικοί φορείς |
| Μελετητές |
| Γεωλόγος |
| Δνση Χωροταξίας ΥΠΕΧΩΔΕ |
| ΓΓ Περίφέρειας |
| Δνση Χωροταξίας (Κεντρική ή Περφερειακή) |
| Υπουργείο Γεωργίας |
| ΥΠΠΟ |
| ΥΠΕΧΩΔΕ/Περιβάλλον |
| Τοπογράφος |
| Γεωτεχνικός |
| Κυκλοφοριολόγος |
| Μελετητης Περιβαλλοντολόγος |
| Δνση Περιβαλλοντικού Σχεδιασμού |
| Δνση Περιβαλλοντος και Χωροταξίας Γενικής Γραμματείας της Περιφέρειας |
| Νομαρχιακό Συμβούλιο |
| Ενδιαφερόμενο Κοινό |
| Εδαφοτεχνικός Μελετητης |
| Συγκοινωνιολόγος Μηχανικός |
| Κύριος του Έργου |
| Γενικός Μελετητής(Ειδικός Συγκοινωνιολόγος) |
| Μελετήτής Οικονομολόγος |
| Δνση Χωροταξίας ΥΠΕΧΩΔΕ ή ΓΓ Περίφέρειας |
| ΥΠΕΧΩΔΕ |
| Ηλεκτρολόγος-Μηχανολόγος |
| ΓΕΜ |
| ΕΥΠΕ ή ΔΙΠΕΧΩ ΓΓ Περιφέρειας |
| Συναρμόδιοι Υπουργοί |
| Συναρμόδια Υπουργεία |

## Schedule

| ID | WBS | Task | Type | Duration | Start | Finish | Predecessors | Baseline start | Baseline finish | Baseline duration | Total slack | Free slack | Resources | Work | Text1 |
| --- | --- | --- | --- | --- | --- | --- | --- | --- | --- | --- | --- | --- | --- | --- | --- |
| 1 | 1 | **Διαδικασία Επιλογής Μελετητή** |  | 180d | 2002-01-01 | 2002-06-30 |  | 2002-01-11 | 2002-01-11 | 0.33d? | 0d |  | Εργοδότης | 10440h | 6Μ |
| 2 | 1.1 | Δημοσίευση Προκήρυξης Μελέτης |  | 45d | 2002-01-01 | 2002-02-15 |  | 2002-01-11 | 2002-01-11 | 0.33d? | 0d |  | Εργοδότης | 1080h | 1.5Μ |
| 3 | 1.2 | Αξιολόγηση Υποψήφιων Μελετητών |  | 30d | 2002-02-15 | 2002-03-17 | 2 | 2002-02-15 | 2002-03-17 | 30d | 0d |  | Εργοδότης | 720h | 1Μ |
| 4 | 1.3 | Επιλογή Μελετητή |  | 15d | 2002-03-17 | 2002-04-01 | 3 | 2002-03-17 | 2002-04-01 | 15d | 0d |  | Εργοδότης | 360h | 0.5Μ |
| 5 | 1.4 | Κοινοποίηση Απόφασης Ανάθεσης |  | 15d | 2002-04-01 | 2002-04-16 | 4 | 2002-04-01 | 2002-04-16 | 15d | 0d |  | Εργοδότης | 360h | 0.5Μ |
| 6 | 1.5 | Διαδικασία Ενστάσεων |  | 75d | 2002-04-16 | 2002-06-30 | 5 | 2002-04-16 | 2002-06-30 | 75d | 0d |  | Εργοδότης; ΓΕΜ | 3600h | 2.5Μ |
| 7 | 1.6 | Ανάθεση Μελέτης | milestone | 0d | 2002-06-30 | 2002-06-30 | 6 | 2002-06-30 | 2002-06-30 | 0d? | 0d |  | Εργοδότης |  | 0Μ |
| 8 | 2 | Κατάρτιση Σύμβασης - Υπογραφή Σύμβασης - Εγκατάσταση Αναδόχου |  | 31d | 2002-06-30 | 2002-07-31 | 7 | 2002-06-30 | 2002-07-31 | 31d | 0d |  | Εργοδότης; Προιστάμενη Αρχή; Διευθύνουσα Υπηρεσία; Γεν. Μελετητής | 2976h | 1Μ |
| 9 | 3 | Επίβλεψη μελέτης |  | 426d | 2002-07-31 | 2003-09-30 | 8 | 2002-07-31 | 2003-12-31 | 518d | 0d |  | Διευθύνουσα Υπηρεσία; Γεν. Μελετητής | 20448h | 14Μ |
| 10 | 4 | Εποπτεία Μελέτης |  | 426d | 2002-07-31 | 2003-09-30 | 9SS | 2002-07-31 | 2003-12-31 | 518d | 0d |  | Προιστάμενη Αρχή; Γεν. Μελετητής | 20448h | 14Μ |
| 11 | 5 | **ΣΤΑΔΙΟ ΙΙ: Προμελέτες Έργων / Μελέτη Περιβαλλοντικών Επιπτώσεων** |  | 254.38d | 2002-07-31 | 2003-04-11 | 10SS | 2002-07-31 | 2003-03-31 | 243d | 0d |  |  | 30416h | 8Μ |
| 12 | 5.1 | Εντολή Έναρξης Σταδίου ΙΙ | milestone | 0d | 2002-07-31 | 2002-07-31 |  | 2002-07-31 | 2002-07-31 | 0d? | 0d |  | Εργοδότης |  | 0Μ |
| 13 | 5.2 | Ευρεση Θεσμοθετημένου ή Προγρ. Πολεοδ. Περιβάλλοντος |  | 30d | 2002-07-31 | 2002-08-30 | 12 | 2002-07-31 | 2002-08-30 | 30d | 0d |  | Διευθύνουσα Υπηρεσία; Γεν. Μελετητής | 1440h | 1Μ |
| 14 | 5.3 | Συλλογή Στοιχείων από Οργανισμούς Κοινής Ωφελείας |  | 30d | 2002-07-31 | 2002-08-30 | 12 | 2002-07-31 | 2002-08-30 | 30d | 396d |  | Διευθύνουσα Υπηρεσία; Γεν. Μελετητής | 1440h | 1Μ |
| 15 | 5.4 | Προμελέτη Κυκλοφοριακού Έργου / Κόμβων / Παράπλευρων Έργων |  | 122d | 2002-07-31 | 2002-11-30 | 13SS | 2002-07-31 | 2002-12-01 | 123d | 0d |  | Διευθύνουσα Υπηρεσία; Γεν. Μελετητής; Κυκλοφοριολόγος | 8784h | 4Μ |
| 16 | 5.5 | Προμελέτη Αποχέτευσης Αποστράγγισης |  | 61d | 2002-09-30 | 2002-11-30 | 15FS-61d | 2002-10-01 | 2002-12-01 | 61d | 0d |  | Γεν. Μελετητής; Διευθύνουσα Υπηρεσία | 2928h | 2Μ |
| 17 | 5.6 | Οριστική Γεωλογική Μελέτη |  | 61d | 2002-09-30 | 2002-11-30 | 16SS | 2002-10-01 | 2002-12-01 | 61d | 0d |  | Διευθύνουσα Υπηρεσία; Γεν. Μελετητής; Γεωλόγος; Γεωτεχνικός | 5856h | 2Μ |
| 18 | 5.7 | Προμελέτη Τεχνικών Εργων |  | 61d | 2002-09-30 | 2002-11-30 | 17SS | 2002-10-01 | 2002-12-01 | 61d | 0d |  | Διευθύνουσα Υπηρεσία; Γεν. Μελετητής | 2928h | 2Μ |
| 19 | 5.8 | Εκπόνηση Μελέτης Περιβαλλοντικών Επιπτώσεων-Μ.Π.Ε. |  | 61d | 2002-09-30 | 2002-11-30 | 18SS | 2002-10-01 | 2002-12-01 | 61d | 183d | 0d | Διευθύνουσα Υπηρεσία; Γεν. Μελετητής; Μελετητης Περιβαλλοντολόγος | 4392h | 2Μ |
| 20 | 5.9 | **Έγκριση Μελέτης Περιβαλλοντικών Επιπτώσεων** |  | 132.38d | 2002-11-30 | 2003-04-11 | 19 | 2002-12-01 | 2003-03-31 | 120d | 171.62d |  |  | 2648h | 4.5Μ |
| 21 | 5.9.1 | Παραλάβή Μ.Π.Ε-¨Ελεγχος-Υποβολή |  | 15d | 2002-11-30 | 2002-12-15 |  | 2002-12-01 | 2002-12-16 | 15d | 183d | 0d | Διευθύνουσα Υπηρεσία | 360h | 0.5Μ |
| 22 | 5.9.2 | Παραλαβή της Μ.Π.Ε-Έλεγχος-Διαβίβαση |  | 15d | 2002-12-15 | 2002-12-30 | 21 | 2002-12-16 | 2003-01-15 | 30d | 183d | 0d | ΕΥΠΕ ή ΔΙΠΕΧΩ ΓΓ Περιφέρειας | 80h | 0.5Μ |
| 23 | 5.9.3 | Παραλαβή της Μ.Π.Ε-Γνωμοδότηση-Διαβίβαση |  | 15d | 2002-12-27 | 2003-01-11 | 22FS-3d | 2002-12-31 | 2003-01-15 | 15d | 262d |  | Συναρμόδια Υπουργεία | 88h | 0.5Μ |
| 24 | 5.9.4 | Νομαρχιακό Συμβούλιο: Παραλαβή-Δημοσίευση Ανάρτηση ΜΠΕ |  | 15d | 2002-12-27 | 2003-01-11 | 22FS-3d | 2003-01-15 | 2003-02-13 | 29d | 172d | 0d | Νομαρχιακό Συμβούλιο | 360h | 0.5Μ |
| 25 | 5.9.5 | Διατύπωση Απόψεων - Αντιρρήσεων - Προτάσεων |  | 15d | 2003-01-11 | 2003-01-26 | 24 | 2003-01-31 | 2003-02-15 | 15d | 172d | 0d | Ενδιαφερόμενο Κοινό | 360h | 0.5Μ |
| 26 | 5.9.6 | Νομαρχιακό Συμβούλιο: Κριτική Άποψη Διαβίβαση |  | 15.38d | 2003-01-26 | 2003-02-10 | 25 | 2003-02-15 | 2003-03-01 | 14d | 171.62d | 0d | Νομαρχιακό Συμβούλιο | 360h | 0.5Μ |
| 27 | 5.9.7 | Σύνταξη Σχεδίου Απόφασης Έγκρισης Περιβαλλοντικών Όρων |  | 30d | 2003-02-10 | 2003-03-12 | 26 | 2003-03-01 | 2003-03-16 | 15d | 171.62d | 0d | ΕΥΠΕ ή ΔΙΠΕΧΩ ΓΓ Περιφέρειας | 160h | 1Μ |
| 28 | 5.9.8 | Υπογραφή Υπουργών ή Γ.Γ. Περιφέρειας |  | 15d | 2003-03-12 | 2003-03-27 | 27 | 2003-03-16 | 2003-03-31 | 15d | 171.62d | 0d | ΥΠΕΧΩΔΕ; ΓΓ Περίφέρειας; Συναρμόδιοι Υπουργοί | 800h | 0.5Μ |
| 29 | 5.9.9 | Έκδοση Απόφασης Έγκρισης Περιβαλλοντικών Όρων |  | 15d | 2003-03-27 | 2003-04-11 | 28 | 2003-03-31 | 2003-03-31 | 15d | 171.62d |  | ΕΥΠΕ ή ΔΙΠΕΧΩ ΓΓ Περιφέρειας | 80h | 0.5Μ |
| 30 | 6 | ¨Εγκριση Σταδίου ΙΙ |  | 31d | 2002-11-30 | 2002-12-31 | 18, 20FF | 2003-02-28 | 2003-03-31 | 31d | 0d |  | Εργοδότης | 744h | 1Μ |

| ID | WBS | Task | Type | Duration | Start | Finish | Predecessors | Baseline start | Baseline finish | Baseline duration | Total slack | Resources | Work | Text1 |
| --- | --- | --- | --- | --- | --- | --- | --- | --- | --- | --- | --- | --- | --- | --- |
| 31 | 7 | **ΣΤΑΔΙΟ ΙΙΙ: Οριστικές Μελέτες Έργων** |  | 120d | 2002-12-31 | 2003-04-30 | 30 | 2003-03-31 | 2003-07-31 | 122d | 0d |  | 23184h | 4Μ |
| 32 | 7.1 | Εντολή Έναρξης Σταδίου ΙΙ | milestone | 0d | 2002-12-31 | 2002-12-31 |  | 2003-03-31 | 2003-03-31 | 0d? | 0d | Εργοδότης |  | 0Μ |
| 33 | 7.2 | Οριστική Μελέτη Κυκλοφοριακού Εργου / Κόμβων |  | 120d | 2002-12-31 | 2003-04-30 | 32 | 2003-03-31 | 2003-07-29 | 120d | 0d | Διευθύνουσα Υπηρεσία; Γεν. Μελετητής | 5760h | 4Μ |
| 34 | 7.3 | Οριστική Μελέτη Αποχέτευσης - Αποστράγγισης |  | 61d | 2003-02-28 | 2003-04-30 | 33SS+59d | 2003-05-30 | 2003-07-29 | 60d | 0d | Διευθύνουσα Υπηρεσία; Γεν. Μελετητής | 2928h | 2Μ |
| 35 | 7.4 | Γεωτεχνικά Οδού και Τεχνικών Έργων |  | 90d | 2002-12-31 | 2003-03-31 | 32 | 2003-03-31 | 2003-07-01 | 92d | 61d | Διευθύνουσα Υπηρεσία; Εδαφοτεχνικός Μελετητης | 4320h | 3Μ |
| 36 | 7.5 | Μελέτη Σήμανσης/ Σηματοδότησης |  | 61d | 2003-02-28 | 2003-04-30 | 32FS+59d | 2003-03-31 | 2003-05-31 | 61d | 0d | Διευθύνουσα Υπηρεσία; Συγκοινωνιολόγος Μηχανικός | 2928h | 2Μ |
| 37 | 7.6 | Οριστική Μελέτη Τεχνικών Εργών |  | 90d | 2003-01-30 | 2003-04-30 | 32FS+30d, 35FS-92d | 2003-03-31 | 2003-07-01 | 92d | 0d | Διευθύνουσα Υπηρεσία; Γεν. Μελετητής | 4320h | 3Μ |
| 38 | 7.7 | Προμελέτη Η/Μ |  | 61d | 2003-02-28 | 2003-04-30 | 32FS+59d | 2003-05-31 | 2003-07-31 | 61d | 0d | Διευθύνουσα Υπηρεσία; Ηλεκτρολόγος-Μηχανολόγος | 2928h | 2Μ |
| 39 | 8 | Εγκριση Σταδίου ΙΙΙ |  | 30d | 2003-04-30 | 2003-05-30 | 31 | 2003-07-31 | 2003-08-31 | 31d | 0d | Εργοδότης | 720h | 1Μ |
| 40 | 9 | **ΣΤΑΔΙΟ V: Λοιπές Μελέτες** |  | 426d | 2002-07-31 | 2003-09-30 | 39 | 2002-07-31 | 2003-12-31 | 518d | 0d |  | 35088h | 3Μ |
| 41 | 9.1 | Κτηματολόγιο |  | 426d | 2002-07-31 | 2003-09-30 | 15SS | 2002-07-31 | 2003-12-31 | 518d | 0d | Διευθύνουσα Υπηρεσία; Γεν. Μελετητής; Τοπογράφος | 30672h | 3Μ |
| 42 | 9.2 | Μελέτες Εφαρμογής |  | 92d | 2003-05-30 | 2003-08-30 | 39 | 2003-09-01 | 2003-12-01 | 91d | 0d | Διευθύνουσα Υπηρεσία; Γεν. Μελετητής | 4416h | 3Μ |
| 43 | 10 | Έγκριση Σταδίου V |  | 31d | 2003-08-30 | 2003-09-30 | 42 | 2003-12-01 | 2004-01-01 | 31d | 0d | Εργοδότης | 744h | 1Μ |
| 44 | 11 | Απαλλοτριώσεις |  | 426d | 2002-07-31 | 2003-09-30 | 41SS, 42SS | 2002-07-31 | 2003-12-31 | 518d | 0d |  |  | 7Μ |
| 45 | 12 | Σύνταξη Τευχών Δημοπράτησης |  | 61d | 2003-07-31 | 2003-09-30 | 39FS+62d | 2003-08-31 | 2003-10-31 | 61d | 0d | Διευθύνουσα Υπηρεσία; Γεν. Μελετητής | 2928h | 2Μ |
