# ΔΕΥΤ_ΕΘΝΙΚΟ ΚΑΙ ΕΠΑΡΧ ΤΕΛ

Schedule from MS Project, 2002-01-01 to 2005-01-31, 24 hours a day.
NAMA SA

## Calendars

- 24 Hours: Mon-Sun 00:00-24:00.

## Resources

| Resource |
| --- |
| Εργοδότης |
| Προιστάμενη Αρχή |
| Διευθύνουσα Υπηρεσία |
| Γενικός Μελετητής |
| Αλλοι τοπικοί φορείς |
| Μελετητές |
| Γεωλόγος |
| Δνση Χωροταξίας ΥΠΕΧΩΔΕ |
| ΓΓ Περίφέρειας |
| Δνση Χωροταξίας (Κεντρική ή Περιφερειακή) |
| Υπουργείο Γεωργίας |
| ΥΠΠΟ |
| ΥΠΕΧΩΔΕ/Περιβάλλον |
| Τοπογράφος |
| Γεωτεχνικός |
| Κυκλοφοριολόγος |
| Μελετητης Περιβαλλοντολόγος |
| Δνση Περιβαλλοντικού Σχεδιασμού |
| Δνση Περιβαλλοντος και Χωροταξίας Γενικής Γραμματείας της Περιφέρειας |
| Νομαρχιακό Συμβούλιο |
| Ενδιαφερόμενο Κοινό |
| Εδαφοτεχνικός Μελετητης |
| Συγκοινωνιολόγος Μηχανικός |
| Κύριος του Έργου |
| Γενικός Μελετητής(Ειδικός Συγκοινωνιολόγος) |
| Μελετήτής Οικονομολόγος |
| Δνση Χωροταξίας ΥΠΕΧΩΔΕ ή ΓΓ Περίφέρειας |
| ΥΠΕΧΩΔΕ |
| Ηλεκτρολόγος-Μηχανολόγος |
| ΓΕΜ |
| ΕΥΠΕ |
| Συναρμόδιες Υπηρεσίες |
| ΕΥΠΕ/ΥΠΕΧΩΔΕ ή ΔΙΠΕΧΩ ΓΓ Περιφέρειας |
| Συναρμόδιοι Υπουργοί |
| Συναρμόδια Υπουργεία |

## Schedule

| ID | WBS | Task | Type | Duration | Start | Finish | Predecessors | Baseline start | Baseline finish | Baseline duration | Total slack | Resources | Work | Text1 |
| --- | --- | --- | --- | --- | --- | --- | --- | --- | --- | --- | --- | --- | --- | --- |
| 1 | 1 | **Διαδικασία Επιλογής Μελετητή** |  | 180d | 2002-01-01 | 2002-06-30 |  | 2002-01-11 | 2002-01-11 | 0.33d? | 0d | Εργοδότης | 10464h | 6Μ |
| 2 | 1.1 | Δημοσίευση Προκήρυξης Μελέτης |  | 45d | 2002-01-01 | 2002-02-15 |  | 2002-01-11 | 2002-01-11 | 0.33d? | 0d | Εργοδότης | 1080h | 1.5Μ |
| 3 | 1.2 | Αξιολόγηση Υποψήφιων Μελετητών |  | 28d | 2002-02-15 | 2002-03-15 | 2 | 2002-02-10 | 2002-03-12 | 30d | 0d | Εργοδότης | 672h | 1Μ |
| 4 | 1.3 | Επιλογή Μελετητή |  | 16d | 2002-03-15 | 2002-03-31 | 3 | 2002-03-12 | 2002-03-27 | 15d | 0d | Εργοδότης | 384h | 0.5Μ |
| 5 | 1.4 | Κοινοποίηση Απόφασης Ανάθεσης |  | 15d | 2002-03-31 | 2002-04-15 | 4 | 2002-03-27 | 2002-04-11 | 15d | 0d | Εργοδότης | 360h | 0.5Μ |
| 6 | 1.5 | Διαδικασία Ενστάσεων |  | 76d | 2002-04-15 | 2002-06-30 | 5 | 2002-04-11 | 2002-06-30 | 80d | 0d | Εργοδότης; ΓΕΜ | 3648h | 2.5Μ |
| 7 | 1.6 | Ανάθεση Μελέτης | milestone | 0d | 2002-06-30 | 2002-06-30 | 6 | 2002-06-30 | 2002-06-30 | 0d? | 0d | Εργοδότης |  | 0Μ |
| 8 | 2 | Κατάρτιση Σύμβασης - Υπογραφή Σύμβασης - Εγκατάσταση Αναδόχου |  | 31d | 2002-06-30 | 2002-07-31 | 7 | 2002-06-30 | 2002-07-31 | 31d | 0d | Εργοδότης; Προιστάμενη Αρχή; Διευθύνουσα Υπηρεσία; Γενικός Μελετητής | 2976h | 1Μ |
| 9 | 3 | Επίβλεψη Μελέτης |  | 915d | 2002-07-31 | 2005-01-31 | 11SS, 8 | 2002-07-31 | 2005-05-31 | 1035d | 0d | Διευθύνουσα Υπηρεσία; Γενικός Μελετητής | 43920h | 30M |
| 10 | 4 | Εποπτεία Μελέτης |  | 915d | 2002-07-31 | 2005-01-31 | 9SS | 2002-07-31 | 2005-05-31 | 1035d | 0d | Προιστάμενη Αρχή; Γενικός Μελετητής | 43920h | 30M |
| 11 | 5 | **ΣΤΑΔΙΟ Ι: Αναγνωριστική Μελέτη Έργου / Προμελέτη Περιβαλλοντικών Επιπτώσεων** |  | 184d | 2002-07-31 | 2003-01-31 | 8 | 2002-07-31 | 2003-03-01 | 213d | 0d |  | 22760h | 8Μ |
| 12 | 5.1 | Κυκλοφοριακή μελέτη / Θέσεις κόμβων |  | 61d | 2002-07-31 | 2002-09-30 |  | 2002-07-31 | 2002-09-29 | 2mo | 0d | Εργοδότης; Γενικός Μελετητής(Ειδικός Συγκοινωνιολόγος) | 2928h | 2Μ |
| 13 | 5.2 | **Αναγνώριση Έργου** |  | 138d | 2002-07-31 | 2002-12-16 | 12SS | 2002-09-29 | 2003-01-30 | 123d | 0d |  | 6984h | 4.5Μ |
| 14 | 5.2.1 | Αναγνώριση έργου - Συγκέντρωση στοιχείων |  | 31d | 2002-07-31 | 2002-08-31 |  | 2002-09-29 | 2002-10-30 | 31d | 0d | Διευθύνουσα Υπηρεσία; Μελετητές; Αλλοι τοπικοί φορείς | 2232h | 1Μ |
| 15 | 5.2.2 | Πρόγραμμα Τοπογραφικών Εργασίων |  | 30d | 2002-08-31 | 2002-09-30 | 14 | 2002-10-30 | 2002-11-14 | 15d | 0d | Διευθύνουσα Υπηρεσία; Γενικός Μελετητής | 1440h | 1Μ |
| 16 | 5.2.3 | Έγκριση Προγράμματος Τοπογραφικών Εργασίων |  | 16d | 2002-09-30 | 2002-10-16 | 15 | 2002-11-14 | 2002-11-30 | 16d | 0d | Εργοδότης | 384h | 0.5Μ |
| 17 | 5.2.4 | Εκπόνηση Προκαταρκτικών Εργασιών |  | 61d | 2002-10-16 | 2002-12-16 | 16 | 2002-11-30 | 2003-01-30 | 61d | 0d | Διευθύνουσα Υπηρεσία; Μελετητές | 2928h | 2Μ |
| 18 | 5.3 | Γεωλογική Αναγνώριση |  | 61d | 2002-10-16 | 2002-12-16 | 16, 13FS-61d | 2002-11-30 | 2003-01-30 | 61d | 0d | Διευθύνουσα Υπηρεσία; Γενικός Μελετητής; Γεωλόγος | 4392h | 2Μ |
| 19 | 5.4 | Εκπόνηση Οικονομοτεχνικής Μελέτης |  | 61d | 2002-10-16 | 2002-12-16 | 18FS-61d | 2002-11-30 | 2003-01-30 | 61d | 0d | Διευθύνουσα Υπηρεσία; Γενικός Μελετητής; Μελετήτής Οικονομολόγος | 4392h | 2Μ |
| 20 | 5.5 | Εκπόνηση Προμελέτης Περιβαλλοντικών Επιπτώσεων (Φ. Π. (ή Απαλλαγής) Χ.) - Υποβολή |  | 76d | 2002-10-16 | 2002-12-31 | 19SS | 2003-01-14 | 2003-03-01 | 46d | 0d | Διευθύνουσα Υπηρεσία; Γενικός Μελετητής | 3648h | 2.5Μ ή 1/6Μ |
| 21 | 5.6 | **Διαδικασία Έκδοσης Προκαταρκτικής Περιβαλλοντικής Εκτίμησης και Αξιολόγησης (Π. Χ.)** |  | 31d | 2002-12-31 | 2003-01-31 | 20 | 2003-03-01 | 2003-03-31 | 30d | 0d |  | 416h | 1Μ |
| 22 | 5.6.1 | Παραλαβή Π.Π.Ε. (Φ. Π. Χ.) - Έλεγχος - Υποβολή |  | 8d | 2002-12-31 | 2003-01-08 |  | 2003-03-01 | 2003-03-04 | 3d | 0d | Διευθύνουσα Υπηρεσία | 192h | 1/6Μ |
| 23 | 5.6.2 | Παραλαβή Π.Π.Ε (Φ.Π.Χ.) - Γνωμοδοτήσεις Συναρμοδιών |  | 15d | 2003-01-08 | 2003-01-23 | 22 | 2003-03-04 | 2003-03-07 | 3d | 0d | Συναρμόδιες Υπηρεσίες; ΕΥΠΕ/ΥΠΕΧΩΔΕ ή ΔΙΠΕΧΩ ΓΓ Περιφέρειας | 176h | 1/6Μ |
| 24 | 5.6.3 | Έκδοση Προκαταρκτικής Περιβαλλοντικής Εκτίμησης και Αξιολόξησης (Π.Χ.) |  | 8d | 2003-01-23 | 2003-01-31 | 23 | 2003-03-25 | 2003-03-31 | 6d | 0d | ΕΥΠΕ/ΥΠΕΧΩΔΕ ή ΔΙΠΕΧΩ ΓΓ Περιφέρειας | 48h | 1/6Μ |
| 25 | 6 | Έγκριση Σταδίου Ι |  | 28d | 2003-01-31 | 2003-02-28 | 24 | 2003-03-31 | 2003-04-30 | 30d | 0d | Εργοδότης | 672h | 1Μ |

| ID | WBS | Task | Type | Duration | Start | Finish | Predecessors | Baseline start | Baseline finish | Baseline duration | Total slack | Free slack | Resources | Work | Text1 |
| --- | --- | --- | --- | --- | --- | --- | --- | --- | --- | --- | --- | --- | --- | --- | --- |
| 26 | 7 | **ΣΤΑΔΙΟ ΙΙ: Προμελέτες έργων / Μελέτη Περιβαλλοντικών Επιπτώσεων** |  | 351d | 2003-02-28 | 2004-02-14 | 25 | 2003-04-30 | 2004-03-31 | 336d | 0d |  |  | 41288h | 11Μ |
| 27 | 7.1 | Εντολή Έναρξης σταδίου ΙΙ | milestone | 0d | 2003-02-28 | 2003-02-28 |  | 2003-04-30 | 2003-04-30 | 0d? | 703d |  | Εργοδότης |  | 0Μ |
| 28 | 7.2 | Εκτέλεση Τοπογραφικών Εργασιών |  | 76d | 2003-02-28 | 2003-05-15 | 16 | 2003-04-30 | 2003-07-14 | 75d | 0d |  | Διευθύνουσα Υπηρεσία; Γενικός Μελετητής; Τοπογράφος | 5472h | 2.5Μ |
| 29 | 7.3 | Προμελέτη Κυκλοφοριακού Έργου |  | 138d | 2003-05-15 | 2003-09-30 | 28 | 2003-07-14 | 2003-11-26 | 135d | 0d |  | Διευθύνουσα Υπηρεσία; Γενικός Μελετητής | 6624h | 4.5Μ |
| 30 | 7.4 | Οριστική Γεωλογική Μελέτη |  | 92d | 2003-06-30 | 2003-09-30 | 29SS+46d | 2003-08-28 | 2003-11-26 | 90d | 489d |  | Διευθύνουσα Υπηρεσία; Γενικός Μελετητής; Γεωλόγος; Γεωτεχνικός | 8832h | 3Μ |
| 31 | 7.5 | Προκαταρκτική Μελέτη Κόμβων και Παράπλευρων Έργων |  | 92d | 2003-06-30 | 2003-09-30 | 29SS+46d | 2003-08-28 | 2003-11-26 | 90d | 0d |  | Διευθύνουσα Υπηρεσία; Γενικός Μελετητής; Κυκλοφοριολόγος | 6624h | 3Μ |
| 32 | 7.6 | Προκαταρκτική Επεξεργασία Τεχνικών Έργων |  | 92d | 2003-06-30 | 2003-09-30 | 31SS | 2003-08-28 | 2003-11-26 | 90d | 365d | 0d | Διευθύνουσα Υπηρεσία; Γενικός Μελετητής | 4416h | 3Μ |
| 33 | 7.7 | Εκπόνηση Μελέτης Περιβαλλοντικών Επιπτώσεων |  | 92d | 2003-06-30 | 2003-09-30 | 32SS | 2003-08-28 | 2003-11-26 | 90d | 365d | 0d | Διευθύνουσα Υπηρεσία; Γενικός Μελετητής; Μελετητης Περιβαλλοντολόγος | 6624h | 3Μ |
| 34 | 7.8 | **Έγκριση Μελέτης Περιβαλλοντικών Επιπτώσεων** |  | 137d | 2003-09-30 | 2004-02-14 | 33 | 2003-11-26 | 2004-03-31 | 126d | 352d |  |  | 2696h | 4.5Μ |
| 35 | 7.8.1 | Παραλάβή ΜΠΕ-¨Ελεγχος-Υποβολή |  | 15d | 2003-09-30 | 2003-10-15 |  | 2003-11-26 | 2003-12-11 | 15d | 365d | 0d | Διευθύνουσα Υπηρεσία | 360h | 0.5Μ |
| 36 | 7.8.2 | Παραλαβή της ΜΠΕ-Έλεγχος-Διαβίβαση |  | 16d | 2003-10-15 | 2003-10-31 | 35 | 2003-12-11 | 2004-01-10 | 30d | 365d | 0d | ΕΥΠΕ/ΥΠΕΧΩΔΕ ή ΔΙΠΕΧΩ ΓΓ Περιφέρειας | 96h | 0.5Μ |
| 37 | 7.8.3 | Παραλαβή της ΜΠΕ-Γνωμοδότηση-Διαβίβαση |  | 15d | 2003-10-31 | 2003-11-15 | 36 | 2003-12-26 | 2004-01-10 | 15d | 441d |  | Συναρμόδια Υπουργεία | 88h | 0.5Μ |
| 38 | 7.8.4 | Νομαρχιακό Συμβούλιο: Παραλαβή - Δημοσίευση Ανάρτηση ΜΠΕ |  | 15d | 2003-10-31 | 2003-11-15 | 36 | 2004-01-10 | 2004-02-09 | 30d | 365d | 0d | Νομαρχιακό Συμβούλιο | 360h | 0.5Μ |
| 39 | 7.8.5 | Διατύπωση Απόψεων - Αντιρρήσεων - Προτάσεων |  | 15d | 2003-11-15 | 2003-11-30 | 38 | 2004-01-25 | 2004-02-14 | 20d | 349d | 0d | Ενδιαφερόμενο Κοινό | 360h | 0.5Μ |
| 40 | 7.8.6 | Νομαρχιακό Συμβούλιο: Κριτική Άποψη Διαβίβαση |  | 15d | 2003-11-30 | 2003-12-15 | 39 | 2004-02-14 | 2004-02-29 | 15d | 350d | 0d | Νομαρχιακό Συμβούλιο | 360h | 0.5Μ |
| 41 | 7.8.7 | Σύνταξη Σχεδίου Απόφασης Έγκρισης Περιβαλλοντικών Όρων |  | 31d | 2003-12-15 | 2004-01-15 | 40 | 2004-02-29 | 2004-03-15 | 15d | 349d | 0d | ΕΥΠΕ/ΥΠΕΧΩΔΕ ή ΔΙΠΕΧΩ ΓΓ Περιφέρειας | 176h | 1Μ |
| 42 | 7.8.8 | Υπογραφή Υπουργών η Γ.Γ. Περιφέρειας |  | 15d | 2004-01-15 | 2004-01-30 | 41 | 2004-03-15 | 2004-03-31 | 16d | 350d | 0d | ΥΠΕΧΩΔΕ; ΓΓ Περίφέρειας; Συναρμόδιοι Υπουργοί | 808h | 0.5Μ |
| 43 | 7.8.9 | Έκδοση Απόφασης Εγκρισης Περιβαλλοντικών Όρων |  | 15d | 2004-01-30 | 2004-02-14 | 42 | 2004-03-31 | 2004-03-31 | 16d | 350d |  | ΕΥΠΕ/ΥΠΕΧΩΔΕ ή ΔΙΠΕΧΩ ΓΓ Περιφέρειας | 88h | 0.5Μ |
| 44 | 8 | ¨Εγκριση Σταδίου ΙΙ |  | 31d | 2003-09-30 | 2003-10-31 | 31 | 2004-02-29 | 2004-03-31 | 31d | 0d |  | Εργοδότης | 744h | 1Μ |
| 45 | 9 | **ΣΤΑΔΙΟ ΙΙΙ: Οριστικές Μελέτες Έργων** |  | 183d | 2003-10-31 | 2004-05-01 | 44 | 2004-03-31 | 2004-09-30 | 183d | 0d |  |  | 51168h | 6Μ |
| 46 | 9.1 | Εντολή Εναρξης Σταδίου ΙΙΙ | milestone | 0d | 2003-10-31 | 2003-10-31 |  | 2004-03-31 | 2004-03-31 | 0d? | 0d |  | Εργοδότης |  | 0Μ |
| 47 | 9.2 | Οριστική Μελέτη Κυκλοφοριακόυ Έργου |  | 183d | 2003-10-31 | 2004-05-01 | 46 | 2004-03-31 | 2004-09-30 | 183d | 0d |  | Διευθύνουσα Υπηρεσία; Γενικός Μελετητής | 8784h | 6Μ |
| 48 | 9.3 | Οριστική Μελέτη Αποχέτευσης - Αποστραγγισης |  | 120d | 2003-12-31 | 2004-04-29 | 47SS+61d | 2004-05-31 | 2004-09-28 | 120d | 3d |  | Διευθύνουσα Υπηρεσία; Γενικός Μελετητής | 5760h | 4Μ |
| 49 | 9.4 | Εκτέλεση Γεωτεχνικών και Λοιπών Ερευνών |  | 122d | 2003-10-31 | 2004-03-01 | 46 | 2004-03-31 | 2004-07-31 | 122d | 0d |  | Διευθύνουσα Υπηρεσία; Εδαφοτεχνικός Μελετητης | 5856h | 4Μ |
| 50 | 9.5 | Μελέτη Σήμανσης/ Ασφάλισης |  | 122d | 2003-10-31 | 2004-03-01 | 46 | 2004-03-31 | 2004-07-29 | 120d | 62d |  | Διευθύνουσα Υπηρεσία; Συγκοινωνιολόγος Μηχανικός | 5856h | 4Μ |
| 51 | 9.6 | Οριστική Μελέτη Κόμβων και Παράπλευρων Έργων |  | 122d | 2003-12-31 | 2004-05-01 | 47SS+61d | 2004-05-31 | 2004-09-28 | 120d | 0d |  | Διευθύνουσα Υπηρεσία; Γενικός Μελετητής; Κυκλοφοριολόγος | 8784h | 4Μ |
| 52 | 9.7 | Γεωτεχνικά Τεχνικών Έργων |  | 122d | 2003-12-31 | 2004-05-01 | 49SS+61d | 2004-05-31 | 2004-09-28 | 120d | 0d |  | Διευθύνουσα Υπηρεσία; Εδαφοτεχνικός Μελετητης | 5856h | 4Μ |
| 53 | 9.8 | Προμελέτη Τεχνικών Εργών |  | 122d | 2003-12-31 | 2004-05-01 | 52SS | 2004-05-31 | 2004-09-28 | 120d | 0d |  | Διευθύνουσα Υπηρεσία; Γενικός Μελετητής | 5856h | 4Μ |
| 54 | 9.9 | Προμελέτη Η/Μ |  | 92d | 2004-01-30 | 2004-05-01 | 53SS+30d | 2004-06-30 | 2004-09-28 | 90d | 0d |  | Διευθύνουσα Υπηρεσία; Ηλεκτρολόγος-Μηχανολόγος | 4416h | 4Μ |
| 55 | 10 | Εγκριση Σταδίου ΙΙΙ |  | 31d | 2004-05-01 | 2004-06-01 | 45 | 2004-09-30 | 2004-10-31 | 31d | 0d |  | Εργοδότης | 744h | 1Μ |

| ID | WBS | Task | Type | Duration | Start | Finish | Predecessors | Baseline start | Baseline finish | Baseline duration | Total slack | Resources | Work | Text1 |
| --- | --- | --- | --- | --- | --- | --- | --- | --- | --- | --- | --- | --- | --- | --- |
| 56 | 11 | **ΣΤΑΔΙΟ ΙV: Οριστικές Μελέτες Λοιπών Έργων** |  | 91d | 2004-06-01 | 2004-08-31 | 55 | 2004-10-31 | 2005-01-31 | 92d | 0d |  | 4368h | 2Μ |
| 57 | 11.1 | Εντολή Έναρξης Σταδίου IV | milestone | 0d | 2004-06-01 | 2004-06-01 |  | 2004-10-31 | 2004-10-31 | 0d? | 0d | Εργοδότης |  | 0Μ |
| 58 | 11.2 | Οριστική Μελέτη Τεχνικών Έργων |  | 91d | 2004-06-01 | 2004-08-31 | 57SS | 2004-10-31 | 2005-01-31 | 92d | 0d | Διευθύνουσα Υπηρεσία; Γενικός Μελετητής | 4368h | 3Μ |
| 59 | 12 | Εγκριση Σταδίου ΙV |  | 30d | 2004-08-31 | 2004-09-30 | 58 | 2005-01-31 | 2005-03-02 | 30d | 0d | Εργοδότης | 720h | 1Μ |
| 60 | 13 | **ΣΤΑΔΙΟ V: Λοιπές Μελέτες** |  | 884d | 2002-08-31 | 2005-01-31 |  | 2004-10-31 | 2005-04-30 | 181d | 0d |  | 68064h | 3Μ |
| 61 | 13.1 | Κτηματολόγιο |  | 884d | 2002-08-31 | 2005-01-31 | 15SS, 58SS | 2004-10-31 | 2005-04-30 | 181d | 0d | Διευθύνουσα Υπηρεσία; Γενικός Μελετητής; Τοπογράφος | 63648h | 3Μ |
| 62 | 13.2 | Μελέτες Εφαρμογής |  | 92d | 2004-09-30 | 2004-12-31 | 59, 61SS | 2004-10-31 | 2005-04-30 | 181d | 0d | Διευθύνουσα Υπηρεσία; Γενικός Μελετητής | 4416h | 3Μ |
| 63 | 14 | Εγκριση Σταδίου V |  | 31d | 2004-12-31 | 2005-01-31 | 62 | 2005-04-30 | 2005-05-31 | 31d | 0d | Εργοδότης | 744h | 1Μ |
| 64 | 15 | Απαλλοτριώσεις |  | 884d | 2002-08-31 | 2005-01-31 | 61SS, 62SS | 2004-10-31 | 2005-05-31 | 212d | 0d |  |  | 7Μ |
| 65 | 16 | Σύνταξη Τευχών Δημοπράτησης |  | 61d | 2004-11-30 | 2005-01-30 | 59FS+61d, 58 | 2005-01-31 | 2005-03-31 | 59d | 1d | Διευθύνουσα Υπηρεσία; Γενικός Μελετητής | 2928h | 2Μ |
