# ΔΕΥΤ_ΕΘΝΙΚΟ ΚΑΙ ΕΠΑΡΧ ΕΓΚ27

Schedule from MS Project, 2002-01-01 to 2004-03-01, 24 hours a day.
NAMA SA

## Calendars

- 24 Hours: Mon-Sun 00:00-24:00.

## Resources

| Resource |
| --- |
| Εργοδότης |
| Προιστάμενη Αρχή |
| Διευθύνουσα Υπηρεσία |
| Γενικός Μελετητής |
| Αλλοι τοπικοί φορείς |
| Μελετητές |
| Γεωλόγος |
| Δνση Χωροταξίας ΥΠΕΧΩΔΕ |
| ΓΓ Περίφέρειας |
| Δνση Χωροταξίας (Κεντρική ή Περιφερειακή) |
| Υπουργείο Γεωργίας |
| ΥΠΠΟ |
| ΥΠΕΧΩΔΕ/Περιβάλλον |
| Τοπογράφος |
| Γεωτεχνικός |
| Κυκλοφοριολόγος |
| Μελετητης Περιβαλλοντολόγος |
| Δνση Περιβαλλοντικού Σχεδιασμού |
| Δνση Περιβαλλοντος και Χωροταξίας Γενικής Γραμματείας της Περιφέρειας |
| Νομαρχιακό Συμβούλιο |
| Ενδιαφερόμενο Κοινό |
| Εδαφοτεχνικός Μελετητης |
| Συγκοινωνιολόγος Μηχανικός |
| Κύριος του Έργου |
| Γενικός Μελετητής(Ειδικός Συγκοινωνιολόγος) |
| Μελετήτής Οικονομολόγος |
| Δνση Χωροταξίας ΥΠΕΧΩΔΕ ή ΓΓ Περίφέρειας |
| ΥΠΕΧΩΔΕ |
| Ηλεκτρολόγος-Μηχανολόγος |
| ΓΕΜ |
| ΕΥΠΕ |
| Συναρμόδιες Υπηρεσίες |
| ΕΥΠΕ/ΥΠΕΧΩΔΕ ή ΔΙΠΕΧΩ ΓΓ Περιφέρειας |
| Συναρμόδιοι Υπουργοί |
| Συναρμόδια Υπουργεία |

## Schedule

| ID | WBS | Task | Type | Duration | Start | Finish | Predecessors | Baseline start | Baseline finish | Baseline duration | Total slack | Free slack | Resources | Work | Text1 |
| --- | --- | --- | --- | --- | --- | --- | --- | --- | --- | --- | --- | --- | --- | --- | --- |
| 1 | 1 | **Διαδικασία Επιλογής Μελετητή** |  | 180d | 2002-01-01 | 2002-06-30 |  | 2002-01-11 | 2002-01-11 | 0.33d? | 0d |  | Εργοδότης | 10464h | 6Μ |
| 2 | 1.1 | Δημοσίευση Προκήρυξης Μελέτης |  | 45d | 2002-01-01 | 2002-02-15 |  | 2002-01-11 | 2002-01-11 | 0.33d? | 0d |  | Εργοδότης | 1080h | 1.5Μ |
| 3 | 1.2 | Αξιολόγηση Υποψήφιων Μελετητών |  | 28d | 2002-02-15 | 2002-03-15 | 2 | 2002-02-10 | 2002-03-12 | 30d | 0d |  | Εργοδότης | 672h | 1Μ |
| 4 | 1.3 | Επιλογή Μελετητή |  | 16d | 2002-03-15 | 2002-03-31 | 3 | 2002-03-12 | 2002-03-27 | 15d | 0d |  | Εργοδότης | 384h | 0.5Μ |
| 5 | 1.4 | Κοινοποίηση Απόφασης Ανάθεσης |  | 15d | 2002-03-31 | 2002-04-15 | 4 | 2002-03-27 | 2002-04-11 | 15d | 0d |  | Εργοδότης | 360h | 0.5Μ |
| 6 | 1.5 | Διαδικασία Ενστάσεων |  | 76d | 2002-04-15 | 2002-06-30 | 5 | 2002-04-11 | 2002-06-30 | 80d | 0d |  | Εργοδότης; ΓΕΜ | 3648h | 2.5Μ |
| 7 | 1.6 | Ανάθεση Μελέτης | milestone | 0d | 2002-06-30 | 2002-06-30 | 6 | 2002-06-30 | 2002-06-30 | 0d? | 0d |  | Εργοδότης |  | 0Μ |
| 8 | 2 | Κατάρτιση Σύμβασης - Υπογραφή Σύμβασης - Εγκατάσταση Αναδόχου |  | 31d | 2002-06-30 | 2002-07-31 | 7 | 2002-06-30 | 2002-07-31 | 31d | 0d |  | Εργοδότης; Προιστάμενη Αρχή; Διευθύνουσα Υπηρεσία; Γενικός Μελετητής | 2976h | 1Μ |
| 9 | 3 | Επίβλεψη Μελέτης |  | 578d | 2002-07-31 | 2004-02-29 | 11SS, 8 | 2002-07-31 | 2005-05-31 | 1035d | 1d | 0d | Διευθύνουσα Υπηρεσία; Γενικός Μελετητής | 27744h | 19M |
| 10 | 4 | Εποπτεία Μελέτης |  | 578d | 2002-07-31 | 2004-02-29 | 9SS | 2002-07-31 | 2005-05-31 | 1035d | 1d |  | Προιστάμενη Αρχή; Γενικός Μελετητής | 27744h | 19M |
| 11 | 5 | **ΣΤΑΔΙΟ Ι: Αναγνωριστική Μελέτη Έργου / Προμελέτη Περιβαλλοντικών Επιπτώσεων** |  | 184d | 2002-07-31 | 2003-01-31 | 8 | 2002-07-31 | 2003-03-01 | 213d | 0d |  |  | 22760h | 8Μ |
| 12 | 5.1 | Κυκλοφοριακή μελέτη / Θέσεις κόμβων |  | 61d | 2002-07-31 | 2002-09-30 |  | 2002-07-31 | 2002-09-29 | 2mo | 0d |  | Εργοδότης; Γενικός Μελετητής(Ειδικός Συγκοινωνιολόγος) | 2928h | 2Μ |
| 13 | 5.2 | **Αναγνώριση Έργου** |  | 138d | 2002-07-31 | 2002-12-16 | 12SS | 2002-09-29 | 2003-01-30 | 123d | 0d |  |  | 6984h | 4.5Μ |
| 14 | 5.2.1 | Αναγνώριση Έργου - Συγκέντρωση στοιχείων |  | 31d | 2002-07-31 | 2002-08-31 |  | 2002-09-29 | 2002-10-30 | 31d | 0d |  | Διευθύνουσα Υπηρεσία; Μελετητές; Αλλοι τοπικοί φορείς | 2232h | 1Μ |
| 15 | 5.2.2 | Πρόγραμμα Τοπογραφικών Εργασίων |  | 30d | 2002-08-31 | 2002-09-30 | 14 | 2002-10-30 | 2002-11-14 | 15d | 0d |  | Διευθύνουσα Υπηρεσία; Γενικός Μελετητής | 1440h | 1Μ |
| 16 | 5.2.3 | Έγκριση Προγράμματος Τοπογραφικών Εργασίων |  | 16d | 2002-09-30 | 2002-10-16 | 15 | 2002-11-14 | 2002-11-30 | 16d | 0d |  | Εργοδότης | 384h | 0.5Μ |
| 17 | 5.2.4 | Εκπόνηση Προκαταρκτικών Εργασιών |  | 61d | 2002-10-16 | 2002-12-16 | 16 | 2002-11-30 | 2003-01-30 | 61d | 0d |  | Διευθύνουσα Υπηρεσία; Μελετητές | 2928h | 2Μ |
| 18 | 5.3 | Γεωλογική Αναγνώριση |  | 61d | 2002-10-16 | 2002-12-16 | 16, 13FS-61d | 2002-11-30 | 2003-01-30 | 61d | 0d |  | Διευθύνουσα Υπηρεσία; Γενικός Μελετητής; Γεωλόγος | 4392h | 2Μ |
| 19 | 5.4 | Εκπόνηση Οικονομοτεχνικής Μελέτης |  | 61d | 2002-10-16 | 2002-12-16 | 18FS-61d | 2002-11-30 | 2003-01-30 | 61d | 0d |  | Διευθύνουσα Υπηρεσία; Γενικός Μελετητής; Μελετήτής Οικονομολόγος | 4392h | 2Μ |
| 20 | 5.5 | Εκπόνηση Προμελέτης Περιβαλλοντικών Επιπτώσεων- Π.Π.Ε. (Φ.Π.Χ. ή Απαλλαγή) - Υποβολή |  | 76d | 2002-10-16 | 2002-12-31 | 19SS | 2003-01-14 | 2003-03-01 | 46d | 0d |  | Διευθύνουσα Υπηρεσία; Γενικός Μελετητής | 3648h | 2.5Μ ή 1/6Μ |
| 21 | 5.6 | **Διαδικασία Έκδοσης Προκαταρκτικής Περιβαλλοντικής Εκτίμησης και Αξιολόγησης (Π.Χ.)** |  | 31d | 2002-12-31 | 2003-01-31 | 20 | 2003-03-01 | 2003-03-31 | 30d | 0d |  |  | 416h | 1Μ |
| 22 | 5.6.1 | Παραλαβή Π.Π.Ε. (Φ.Π.Χ.) - Έλεγχος - Υποβολή |  | 8d | 2002-12-31 | 2003-01-08 |  | 2003-03-01 | 2003-03-04 | 3d | 0d |  | Διευθύνουσα Υπηρεσία | 192h | 1/6Μ |
| 23 | 5.6.2 | Παραλαβή Π.Π.Ε. (Φ.Π.Χ.) - Γνωμοδοτήσεις Συναρμοδιών |  | 15d | 2003-01-08 | 2003-01-23 | 22 | 2003-03-04 | 2003-03-07 | 3d | 0d |  | Συναρμόδιες Υπηρεσίες; ΕΥΠΕ/ΥΠΕΧΩΔΕ ή ΔΙΠΕΧΩ ΓΓ Περιφέρειας | 176h | 1/6Μ |
| 24 | 5.6.3 | Έκδοση Προκαταρκτικής Περιβαλλοντικής Εκτίμησης και Αξιολόγησης (Π.Χ.) |  | 8d | 2003-01-23 | 2003-01-31 | 23 | 2003-03-25 | 2003-03-31 | 6d | 0d |  | ΕΥΠΕ/ΥΠΕΧΩΔΕ ή ΔΙΠΕΧΩ ΓΓ Περιφέρειας | 48h | 1/6Μ |
| 25 | 6 | Έγκριση Σταδίου Ι |  | 28d | 2003-01-31 | 2003-02-28 | 24 | 2003-03-31 | 2003-04-30 | 30d | 0d |  | Εργοδότης | 672h | 1Μ |

| ID | WBS | Task | Type | Duration | Start | Finish | Predecessors | Baseline start | Baseline finish | Baseline duration | Total slack | Free slack | Resources | Work | Text1 |
| --- | --- | --- | --- | --- | --- | --- | --- | --- | --- | --- | --- | --- | --- | --- | --- |
| 26 | 7 | **ΣΤΑΔΙΟ ΙΙ: Προμελέτες έργων / Μελέτη Περιβαλλοντικών Επιπτώσεων** |  | 352d | 2003-02-28 | 2004-02-15 | 25 | 2003-04-30 | 2004-03-31 | 336d | 0d |  |  | 36856h | 11Μ |
| 27 | 7.1 | Εντολή Έναρξης σταδίου ΙΙ | milestone | 0d | 2003-02-28 | 2003-02-28 |  | 2003-04-30 | 2003-04-30 | 0d? | 703d |  | Εργοδότης |  | 0Μ |
| 28 | 7.2 | Εκτέλεση Τοπογραφικών Εργασιών |  | 76d | 2003-02-28 | 2003-05-15 | 16 | 2003-04-30 | 2003-07-14 | 75d | 0d |  | Διευθύνουσα Υπηρεσία; Γενικός Μελετητής; Τοπογράφος | 5472h | 2.5Μ |
| 29 | 7.3 | Προμελέτη Κυκλοφοριακού Έργου |  | 138d | 2003-05-15 | 2003-09-30 | 28 | 2003-07-14 | 2003-11-26 | 135d | 0d |  | Διευθύνουσα Υπηρεσία; Γενικός Μελετητής | 6624h | 4.5Μ |
| 30 | 7.4 | Οριστική Γεωλογική Μελέτη |  | 92d | 2003-06-30 | 2003-09-30 | 29SS+46d | 2003-08-28 | 2003-11-26 | 90d | 153d |  | Διευθύνουσα Υπηρεσία; Γενικός Μελετητής; Γεωλόγος; Γεωτεχνικός | 8832h | 3Μ |
| 31 | 7.5 | Προκαταρκτική Μελέτη Κόμβων και Παράπλευρων Έργων |  | 92d | 2003-06-30 | 2003-09-30 | 29SS+46d | 2003-08-28 | 2003-11-26 | 90d | 0d |  | Διευθύνουσα Υπηρεσία; Γενικός Μελετητής; Κυκλοφοριολόγος | 6624h | 3Μ |
| 32 | 7.6 | Εκπόνηση Μελέτης Περιβαλλοντικών Επιπτώσεων |  | 92d | 2003-06-30 | 2003-09-30 | 31SS | 2003-08-28 | 2003-11-26 | 90d | 14d | 0d | Διευθύνουσα Υπηρεσία; Γενικός Μελετητής; Μελετητης Περιβαλλοντολόγος | 6624h | 3Μ |
| 33 | 7.7 | **Έγκριση Μελέτης Περιβαλλοντικών Επιπτώσεων-Μ.Π.Ε.** |  | 138d | 2003-09-30 | 2004-02-15 | 32 | 2003-11-26 | 2004-03-31 | 126d | 14d |  |  | 2680h | 4.5Μ |
| 34 | 7.7.1 | Παραλάβή Μ.Π.Ε-¨Ελεγχος-Υποβολή |  | 15d | 2003-09-30 | 2003-10-15 |  | 2003-11-26 | 2003-12-11 | 15d | 14d | 0d | Διευθύνουσα Υπηρεσία | 360h | 0.5Μ |
| 35 | 7.7.2 | Παραλαβή της Μ.Π.Ε-Έλεγχος-Διαβίβαση |  | 16d | 2003-10-15 | 2003-10-31 | 34 | 2003-12-11 | 2004-01-10 | 30d | 14d | 0d | ΕΥΠΕ/ΥΠΕΧΩΔΕ ή ΔΙΠΕΧΩ ΓΓ Περιφέρειας | 96h | 0.5Μ |
| 36 | 7.7.3 | Παραλαβή της Μ.Π.Ε-Γνωμοδότηση-Διαβίβαση |  | 15d | 2003-10-31 | 2003-11-15 | 35 | 2003-12-26 | 2004-01-10 | 15d | 107d |  | Συναρμόδια Υπουργεία | 80h | 0.5Μ |
| 37 | 7.7.4 | Νομαρχιακό Συμβούλιο: Παραλαβή - Δημοσίευση Ανάρτηση Μ.Π.Ε |  | 15d | 2003-10-31 | 2003-11-15 | 35 | 2004-01-10 | 2004-02-09 | 30d | 14d | 0d | Νομαρχιακό Συμβούλιο | 360h | 0.5Μ |
| 38 | 7.7.5 | Διατύπωση Απόψεων - Αντιρρήσεων - Προτάσεων |  | 15d | 2003-11-15 | 2003-11-30 | 37 | 2004-01-25 | 2004-02-14 | 20d | 14d | 0d | Ενδιαφερόμενο Κοινό | 360h | 0.5Μ |
| 39 | 7.7.6 | Νομαρχιακό Συμβούλιο: Κριτική Άποψη Διαβίβαση |  | 15d | 2003-11-30 | 2003-12-15 | 38 | 2004-02-14 | 2004-02-29 | 15d | 14d | 0d | Νομαρχιακό Συμβούλιο | 360h | 0.5Μ |
| 40 | 7.7.7 | Σύνταξη Σχεδίου Απόφασης Έγκρισης Περιβαλλοντικών Όρων |  | 32d | 2003-12-15 | 2004-01-16 | 39 | 2004-02-29 | 2004-03-15 | 15d | 14d | 0d | ΕΥΠΕ/ΥΠΕΧΩΔΕ ή ΔΙΠΕΧΩ ΓΓ Περιφέρειας | 176h | 1Μ |
| 41 | 7.7.8 | Υπογραφή Υπουργών η Γ.Γ. Περιφέρειας |  | 15d | 2004-01-16 | 2004-01-31 | 40 | 2004-03-15 | 2004-03-31 | 16d | 14d | 0d | ΥΠΕΧΩΔΕ; ΓΓ Περίφέρειας; Συναρμόδιοι Υπουργοί | 808h | 0.5Μ |
| 42 | 7.7.9 | Έκδοση Απόφασης Εγκρισης Περιβαλλοντικών Όρων |  | 15d | 2004-01-31 | 2004-02-15 | 41 | 2004-03-31 | 2004-03-31 | 16d | 15d |  | ΕΥΠΕ/ΥΠΕΧΩΔΕ ή ΔΙΠΕΧΩ ΓΓ Περιφέρειας | 80h | 0.5Μ |
| 43 | 8 | ¨Εγκριση Σταδίου ΙΙ |  | 31d | 2003-09-30 | 2003-10-31 | 31 | 2004-02-29 | 2004-03-31 | 31d | 0d |  | Εργοδότης | 744h | 1Μ |
| 44 | 9 | **ΣΤΑΔΙΟ IΙΙ: Λοιπές Προμελέτες** |  | 212d | 2003-02-28 | 2003-09-28 | 26SS | 2003-02-28 | 2003-08-27 | 180d | 2d |  |  | 10176h | 6Μ |
| 45 | 9.1 | Προκαταρκτική Επεξεργασία Τεχνικών Έργων |  | 60d | 2003-02-28 | 2003-04-29 |  | 2003-02-28 | 2003-04-29 | 60d | 2d | 0d | Διευθύνουσα Υπηρεσία; Γενικός Μελετητής | 2880h | 2Μ |
| 46 | 9.2 | Γεωτεχνικά Τεχνικών Έργων |  | 62d | 2003-04-29 | 2003-06-30 | 45 | 2003-04-29 | 2003-06-28 | 60d | 2d | 0d | Διευθύνουσα Υπηρεσία; Γεωτεχνικός | 2976h | 2Μ |
| 47 | 9.3 | Προμελέτη Τεχνικών Έργων |  | 90d | 2003-06-30 | 2003-09-28 | 46 | 2003-06-28 | 2003-08-27 | 60d | 2d |  | Διευθύνουσα Υπηρεσία; Γενικός Μελετητής | 4320h | 3Μ |
| 48 | 10 | Έγκριση Σταδίου ΙΙΙ |  | 30d | 2003-09-30 | 2003-10-30 | 43SS, 47 | 2003-09-30 | 2003-10-30 | 30d | 0d |  | Εργοδότης | 720h | 1Μ |
| 49 | 11 | **ΣΤΑΔΙΟ IV: Λοιπές Μελέτες** |  | 547d | 2002-08-31 | 2004-02-29 |  | 2004-10-31 | 2005-04-30 | 181d | 1d |  |  | 43800h | 3Μ |
| 50 | 11.1 | Κτηματολόγιο |  | 547d | 2002-08-31 | 2004-02-29 | 15SS | 2004-10-31 | 2005-04-30 | 181d | 1d | 0d | Διευθύνουσα Υπηρεσία; Γενικός Μελετητής; Τοπογράφος | 39384h | 3M |
| 51 | 11.2 | Μελέτες Εφαρμογής |  | 92d | 2003-10-30 | 2004-01-30 | 48 | 2004-10-31 | 2005-04-30 | 181d | 0d |  | Διευθύνουσα Υπηρεσία; Γενικός Μελετητής | 4416h | 3Μ |
| 52 | 12 | Εγκριση Σταδίου V |  | 31d | 2004-01-30 | 2004-03-01 | 51 | 2005-04-30 | 2005-05-31 | 31d | 0d |  | Εργοδότης | 744h | 1Μ |
| 53 | 13 | Απαλλοτριώσεις |  | 547d | 2002-08-31 | 2004-02-29 | 50SS | 2004-10-31 | 2005-05-31 | 212d | 1d |  |  |  | 7Μ |
| 54 | 14 | Σύνταξη Τευχών Δημοπράτησης |  | 60d | 2003-12-31 | 2004-02-29 | 48FS+62d | 2005-01-31 | 2005-03-31 | 59d | 1d |  | Διευθύνουσα Υπηρεσία; Γενικός Μελετητής | 2880h | 2Μ |
