# ΚΟΙΝ-ΑΓΡ-ΔΑΣ_ΔΡΟΜΟΙΤΕΛ

Schedule from MS Project, 2002-01-01 to 2004-04-30, 24 hours a day.
NAMA SA

## Calendars

- 24 Hours: Mon-Sun 00:00-24:00.

## Resources

| Resource |
| --- |
| Εργοδότης |
| Προιστάμενη Αρχή |
| Διευθύνουσα Υπηρεσία |
| Γενικός Μελετητής |
| Αλλοι τοπικοί φορείς |
| Μελετητές |
| Γεωλόγος |
| Δνση Χωροταξίας ΥΠΕΧΩΔΕ |
| ΓΓ Περίφέρειας |
| Δνση Χωροταξίας (Κεντρική ή Περιφερειακή) |
| Υπουργείο Γεωργίας |
| ΥΠΠΟ |
| ΥΠΕΧΩΔΕ/Περιβάλλον |
| Τοπογράφος |
| Γεωτεχνικός |
| Κυκλοφοριολόγος |
| Μελετητης Περιβαλλοντολόγος |
| Δνση Περιβαλλοντικού Σχεδιασμού |
| Δνση Περιβαλλοντος και Χωροταξίας Γενικής Γραμματείας της Περιφέρειας |
| Νομαρχιακό Συμβούλιο |
| Ενδιαφερόμενο Κοινό |
| Εδαφοτεχνικός Μελετητης |
| Συγκοινωνιλόγος Μηχανικός |
| Κύριος του Έργου |
| Γενικός Μελετητής(Ειδικός Συγκοινωνιολόγος) |
| Μελετήτής Οικονομολόγος |
| Δνση Χωροταξίας ΥΠΕΧΩΔΕ ή ΓΓ Περίφέρειας |
| ΥΠΕΧΩΔΕ |
| Ηλεκτρολόγος-Μηχανολόγος |
| ΓΕΜ |
| ΕΥΠΕ/ΥΠΕΧΩΔΕ ή ΔΙΠΕΧΩ ΓΓ Περιφέρειας |
| Συναρμόδιες Υπηρεσίες |
| Συναρμόδιοι Υπουργοί |
| Συναρμόδια Υπουργεία |

## Schedule

| ID | WBS | Task | Type | Duration | Start | Finish | Predecessors | Baseline start | Baseline finish | Baseline duration | Total slack | Resources | Work | Text1 |
| --- | --- | --- | --- | --- | --- | --- | --- | --- | --- | --- | --- | --- | --- | --- |
| 1 | 1 | **Διαδικασία Επιλογής μελετητή** |  | 180d | 2002-01-01 | 2002-06-30 |  | 2002-01-11 | 2002-01-11 | 0.33d? | 0d | Εργοδότης | 10440h | 6Μ |
| 2 | 1.1 | Δημοσίευση Προκήρυξης Μελέτης |  | 45d | 2002-01-01 | 2002-02-15 |  | 2002-01-11 | 2002-01-11 | 0.33d? | 0d | Εργοδότης | 1080h | 1.5Μ |
| 3 | 1.2 | Αξιολόγηση Υποψήφιων μελετητών |  | 30d | 2002-02-15 | 2002-03-17 | 2 | 2002-02-15 | 2002-03-17 | 30d | 0d | Εργοδότης | 720h | 1Μ |
| 4 | 1.3 | Επιλογή μελετητή |  | 15d | 2002-03-17 | 2002-04-01 | 3 | 2002-03-17 | 2002-04-01 | 15d | 0d | Εργοδότης | 360h | 0.5Μ |
| 5 | 1.4 | Κοινοποίηση απόφασης ανάθεσης |  | 15d | 2002-04-01 | 2002-04-16 | 4 | 2002-04-01 | 2002-04-16 | 15d | 0d | Εργοδότης | 360h | 0.5Μ |
| 6 | 1.5 | Διαδικασία ενστάσεων |  | 75d | 2002-04-16 | 2002-06-30 | 5 | 2002-04-16 | 2002-06-30 | 75d | 0d | Εργοδότης; ΓΕΜ | 3600h | 2.5Μ |
| 7 | 1.6 | Ανάθεση Μελέτης | milestone | 0d | 2002-06-30 | 2002-06-30 | 6 | 2002-06-30 | 2002-06-30 | 0d? | 0d | Εργοδότης |  | 0Μ |
| 8 | 2 | Κατάρτιση Σύμβασης - Υπογραφή Σύμβασης - Εγκατάσταση Αναδόχου |  | 31d | 2002-06-30 | 2002-07-31 | 7 | 2002-06-30 | 2002-07-31 | 31d | 0d | Εργοδότης; Προιστάμενη Αρχή; Διευθύνουσα Υπηρεσία; Γενικός Μελετητής | 2976h | 6Μ |
| 9 | 3 | Επίβλεψη Μελέτης |  | 638d | 2002-07-31 | 2004-04-29 | 8 | 2002-07-31 | 2004-04-29 | 638d | 0d | Διευθύνουσα Υπηρεσία; Γενικός Μελετητής | 30624h | 21Μ |
| 10 | 4 | Εποπτεία Μελέτης |  | 638d | 2002-07-31 | 2004-04-29 | 9SS | 2002-07-31 | 2004-04-29 | 638d | 0d | Προιστάμενη Αρχή; Γενικός Μελετητής | 30624h | 21Μ |
| 11 | 5 | **ΣΤΑΔΙΟ Ι: Αναγνωριστική Μελέτη Έργου / Προμελέτη Περιβαλλοντικών Επιπτώσεων** |  | 184d | 2002-07-31 | 2003-01-31 | 10SS | 2002-07-31 | 2003-01-31 | 184d | 0d |  | 13184h | 6Μ |
| 12 | 5.1 | **Αναγνώριση έργου** |  | 138d | 2002-07-31 | 2002-12-16 |  | 2002-07-31 | 2002-12-16 | 138d | 0d |  | 6960h | 4.5Μ |
| 13 | 5.1.1 | Αναγνώριση έργου - Συγκέντρωση στοιχείων |  | 30d | 2002-07-31 | 2002-08-30 |  | 2002-07-31 | 2002-08-30 | 30d | 0d | Διευθύνουσα Υπηρεσία; Μελετητές; Αλλοι τοπικοί φορείς | 2160h | 1Μ |
| 14 | 5.1.2 | Πρόγραμμα Τοπογραφικών Εργασίων |  | 31d | 2002-08-30 | 2002-09-30 | 13 | 2002-08-30 | 2002-09-30 | 31d | 0d | Διευθύνουσα Υπηρεσία; Γενικός Μελετητής | 1488h | 1Μ |
| 15 | 5.1.3 | Έγκριση Προγράμματος Τοπογραφικών Εργασίων |  | 16d | 2002-09-30 | 2002-10-16 | 14 | 2002-09-30 | 2002-10-16 | 16d | 0d | Εργοδότης | 384h | 0.5Μ |
| 16 | 5.1.4 | Εκπόνηση Προκαταρκτικών Εργασιών |  | 61d | 2002-10-16 | 2002-12-16 | 15 | 2002-10-16 | 2002-12-16 | 61d | 0d | Διευθύνουσα Υπηρεσία; Μελετητές | 2928h | 2Μ |
| 17 | 5.2 | Γεωλογική Αναγνώριση |  | 60d | 2002-10-16 | 2002-12-15 | 15, 12FS-61d | 2002-10-16 | 2002-12-15 | 60d | 0d | Διευθύνουσα Υπηρεσία; Γενικός Μελετητής; Γεωλόγος | 4320h | 2Μ |
| 18 | 5.3 | Εκπόνηση Προμελέτης Περιβαλλοντικών Επιπτώσεςων (Φ.Π.Χ. (ή Απαλλαγής)) - Υποβολή |  | 31d | 2002-11-30 | 2002-12-31 | 17FS-15d | 2002-11-30 | 2002-12-31 | 31d | 0d | Διευθύνουσα Υπηρεσία; Γενικός Μελετητής | 1488h | 1Μ ή 1/6Μ |
| 19 | 5.4 | **Διαδικασία Προκαταρκτικής Περιβαλλοντικής Εκτίμησης και Αξιολόγησης (Π. Χ.)** |  | 31d | 2002-12-31 | 2003-01-31 | 18 | 2002-12-31 | 2003-01-31 | 31d | 0d |  | 416h | 1Μ |
| 20 | 5.4.1 | Παραλαβή Π.Π.Ε. (Φ.Π.Χ.) - Έλεγχος - Υποβολής |  | 8d | 2002-12-31 | 2003-01-08 |  | 2002-12-31 | 2003-01-05 | 5d | 0d | Διευθύνουσα Υπηρεσία | 192h | 0.25Μ |
| 21 | 5.4.2 | Παραλαβή Π.Π.Ε. (Φ.Π.Χ.) - Γνωμοδοτήσεις Συναρμοδιών |  | 15d | 2003-01-08 | 2003-01-23 | 20 | 2003-01-05 | 2003-01-10 | 5d | 0d | ΕΥΠΕ/ΥΠΕΧΩΔΕ ή ΔΙΠΕΧΩ ΓΓ Περιφέρειας; Συναρμόδιες Υπηρεσίες | 176h | 0.5Μ |
| 22 | 5.4.3 | Έκδοση Προκαταρκτικής Περιβαλλοντικής Εκτίμησης και Αξιολόγησης (Π. Χ.) |  | 8d | 2003-01-23 | 2003-01-31 | 21 | 2003-01-25 | 2003-01-31 | 6d | 0d | ΕΥΠΕ/ΥΠΕΧΩΔΕ ή ΔΙΠΕΧΩ ΓΓ Περιφέρειας | 48h | 0.25Μ |
| 23 | 6 | Έγκριση Σταδίου Ι |  | 28d | 2003-01-31 | 2003-02-28 | 22 | 2003-01-31 | 2003-02-28 | 28d | 0d | Εργοδότης | 672h | 1Μ |
| 24 | 7 | **ΣΤΑΔΙΟ ΙΙΙ: Οριστικές Μελέτες Έργων** |  | 228d | 2003-02-28 | 2003-10-14 | 23 | 2003-02-28 | 2003-09-30 | 214d | 0d |  | 19672h | 7Μ |
| 25 | 7.1 | Εντολή Έναρξης Σταδίου ΙΙΙ | milestone | 0d | 2003-02-28 | 2003-02-28 |  | 2003-02-28 | 2003-02-28 | 0d? | 0d |  |  | 0Μ |
| 26 | 7.2 | Οριστική Μελέτη Γεωμετρικού Σχεδιασμού |  | 92d | 2003-02-28 | 2003-05-31 | 25 | 2003-02-28 | 2003-05-31 | 92d | 0d | Διευθύνουσα Υπηρεσία; Γενικός Μελετητής; Κυκλοφοριολόγος | 6624h | 3Μ |
| 27 | 7.3 | Οριστική Μελέτη Αποχέτευσης |  | 62d | 2003-03-30 | 2003-05-31 | 26SS+30d | 2003-03-30 | 2003-05-31 | 62d | 335d | Διευθύνουσα Υπηρεσία; Γενικός Μελετητής | 2976h | 2Μ |
| 28 | 7.4 | Εκτέλεση Γεωτεχνικών και λοιπών Ερευνών |  | 61d | 2003-02-28 | 2003-04-30 | 26SS | 2003-02-28 | 2003-04-30 | 61d | 366d | Διευθύνουσα Υπηρεσία; Εδαφοτεχνικός Μελετητης | 2928h | 2Μ |
| 29 | 7.5 | Μελέτη Περιβαλλοντικών Επιπώσεων |  | 62d | 2003-03-30 | 2003-05-31 | 26SS+30d | 2003-03-30 | 2003-05-30 | 61d | 0d | Διευθύνουσα Υπηρεσία; Γενικός Μελετητής; Μελετητης Περιβαλλοντολόγος | 4464h | 2Μ |

| ID | WBS | Task | Type | Duration | Start | Finish | Predecessors | Baseline start | Baseline finish | Baseline duration | Total slack | Free slack | Resources | Work | Text1 |
| --- | --- | --- | --- | --- | --- | --- | --- | --- | --- | --- | --- | --- | --- | --- | --- |
| 30 | 7.6 | **Έγκριση Μελέτης Περιβαλλοντικών Επιπτώσεων** |  | 136d | 2003-05-31 | 2003-10-14 | 29 | 2003-05-30 | 2003-09-30 | 123d | 0d |  |  | 2680h | 4.5Μ |
| 31 | 7.6.1 | Παραλάβή ΜΠΕ- Έλεγχος-Υποβολή |  | 15d | 2003-05-31 | 2003-06-15 |  | 2003-05-30 | 2003-06-14 | 15d | 0d |  | Διευθύνουσα Υπηρεσία | 360h | 0.5Μ |
| 32 | 7.6.2 | Παραλαβή της ΜΠΕ-Έλεγχος-Διαβίβαση |  | 15d | 2003-06-15 | 2003-06-30 | 31 | 2003-06-14 | 2003-06-29 | 15d | 0d |  | ΕΥΠΕ/ΥΠΕΧΩΔΕ ή ΔΙΠΕΧΩ ΓΓ Περιφέρειας | 80h | 0.5Μ |
| 33 | 7.6.3 | Παραλαβή της ΜΠΕ-Γνωμοδότηση-Διαβίβαση |  | 15d | 2003-06-30 | 2003-07-15 | 32 | 2003-06-29 | 2003-07-14 | 15d | 91d |  | Συναρμόδια Υπουργεία | 88h | 0.5Μ |
| 34 | 7.6.4 | Νομαρχιακό Συμβούλιο: Παραλαβή-Δημοσίευση Ανάρτηση ΜΠΕ |  | 15d | 2003-06-30 | 2003-07-15 | 32 | 2003-06-29 | 2003-07-14 | 15d | 0d |  | Νομαρχιακό Συμβούλιο | 360h | 0.5Μ |
| 35 | 7.6.5 | Διατύπωση απόψεων - Αντιρρήσεων - Προτάσεων |  | 16d | 2003-07-15 | 2003-07-31 | 34 | 2003-07-07 | 2003-07-22 | 15d | 0d |  | Ενδιαφερόμενο Κοινό | 384h | 0.5Μ |
| 36 | 7.6.6 | Νομαρχιακό Συμβούλιο: Κριτική Άποψη Διαβίβαση |  | 15d | 2003-07-31 | 2003-08-15 | 35 | 2003-07-16 | 2003-07-31 | 15d | 0d |  | Νομαρχιακό Συμβούλιο | 360h | 0.5Μ |
| 37 | 7.6.7 | Σύνταξη Σχεδίου Απόφασης Έγκρισης Περιβαλλοντικών Όρων |  | 30d | 2003-08-15 | 2003-09-14 | 36 | 2003-07-31 | 2003-08-15 | 15d | 0d |  | ΕΥΠΕ/ΥΠΕΧΩΔΕ ή ΔΙΠΕΧΩ ΓΓ Περιφέρειας | 168h | 1Μ |
| 38 | 7.6.8 | Υπογραφή Υπουργών η Γ.Γ. Περιφέρειας |  | 15d | 2003-09-14 | 2003-09-29 | 37 | 2003-08-15 | 2003-09-14 | 30d | 0d |  | ΥΠΕΧΩΔΕ; ΓΓ Περίφέρειας; Συναρμόδιοι Υπουργοί | 800h | 0.5Μ |
| 39 | 7.6.9 | Έκδοση Απόφασης Έγκρισης Περιβαλλοντικών Όρων | milestone | 15d | 2003-09-29 | 2003-10-14 | 38 | 2003-09-14 | 2003-09-30 | 16d | 0d |  | ΕΥΠΕ/ΥΠΕΧΩΔΕ ή ΔΙΠΕΧΩ ΓΓ Περιφέρειας | 80h | 0.5Μ |
| 40 | 8 | Εγκριση Σταδίου ΙΙΙ |  | 31d | 2003-09-13 | 2003-10-14 | 30FF | 2003-08-30 | 2003-09-30 | 31d | 0d |  | Εργοδότης | 744h | 1Μ |
| 41 | 9 | **ΣΤΑΔΙΟ ΙV: Οριστικές Μελέτες Λοιπών Έργων** |  | 61d | 2003-10-14 | 2003-12-14 | 40 | 2003-09-30 | 2003-11-30 | 61d | 0d |  |  | 2928h | 2Μ |
| 42 | 9.1 | Εντολή Εναρξης Σταδίου IV | milestone | 0d | 2003-10-14 | 2003-10-14 |  | 2003-09-30 | 2003-09-30 | 0d? | 0d |  | Εργοδότης |  | 0Μ |
| 43 | 9.2 | Οριστική Μελέτη Τεχνικών Έργων |  | 61d | 2003-10-14 | 2003-12-14 | 42 | 2003-09-30 | 2003-11-30 | 61d | 0d |  | Διευθύνουσα Υπηρεσία; Γενικός Μελετητής | 2928h | 2Μ |
| 44 | 10 | Εγκριση Σταδίου ΙV |  | 31d | 2003-12-14 | 2004-01-14 | 43 | 2003-11-30 | 2003-12-31 | 31d | 0d |  | Εργοδότης | 744h | 1Μ |
| 45 | 11 | **ΣΤΑΔΙΟ V: Λοιπές Μελέτες** |  | 578d | 2002-08-30 | 2004-03-30 |  | 2002-08-30 | 2004-04-29 | 608d | 1d |  |  | 41616h | 4Μ |
| 46 | 11.1 | Κτηματολόγιο |  | 578d | 2002-08-30 | 2004-03-30 | 14SS | 2002-08-30 | 2004-04-29 | 608d | 1d | 0d | Διευθύνουσα Υπηρεσία; Γενικός Μελετητής; Τοπογράφος | 41616h | 3Μ |
| 47 | 12 | Εγκριση Σταδίου V |  | 30d | 2004-03-30 | 2004-04-29 | 46 | 2004-03-30 | 2004-04-29 | 30d | 1d |  | Εργοδότης | 720h | 1Μ |
| 48 | 13 | Απαλλοτριώσεις |  | 608d | 2002-08-30 | 2004-04-29 | 46SS | 2002-08-30 | 2004-04-29 | 608d | 15d |  |  |  | 7Μ |
| 49 | 14 | Σύνταξη Τευχών Δημοπράτησης |  | 60d | 2004-03-01 | 2004-04-30 | 44FS+47d | 2003-12-31 | 2004-02-29 | 60d | 0d |  | Διευθύνουσα Υπηρεσία; Γενικός Μελετητής | 2880h | 2Μ |
