# ΥΠΕΡΑΣΤ_ΟΔΟΠ ΤΕΛΙΚΟ

Schedule from MS Project, 2002-01-01 to 2005-01-31, 24 hours a day.
NAMA SA

## Calendars

- 24 Hours: Mon-Sun 00:00-24:00.

## Resources

| Resource | Cost per use |
| --- | --- |
| Εργοδότης | 8928000 |
| Προιστάμενη Αρχή |  |
| Διευθύνουσα Υπηρεσία |  |
| Γενικός Μελετητής |  |
| Αλλοι τοπικοί φορείς |  |
| Μελετητές |  |
| Γεωλόγος |  |
| Δνση Χωροταξίας ΥΠΕΧΩΔΕ |  |
| ΓΓ Περίφέρειας |  |
| Δνση Χωροταξίας (Κεντρική ή Περιφερειακή) |  |
| Υπουργείο Γεωργίας |  |
| ΥΠΠΟ |  |
| ΥΠΕΧΩΔΕ/Περιβάλλον |  |
| Τοπογράφος |  |
| Γεωτεχνικός |  |
| Κυκλοφοριολόγος |  |
| Μελετητης Περιβαλλοντολόγος |  |
| Δνση Περιβαλλοντικού Σχεδιασμού |  |
| Δνση Περιβαλλοντος και Χωροταξίας Γενικής Γραμματείας της Περιφέρειας |  |
| Νομαρχιακό Συμβούλιο |  |
| Ενδιαφερόμενο Κοινό |  |
| Εδαφοτεχνικός Μελετητης |  |
| Συγκοινωνιλόγος Μηχανικός |  |
| Κύριος του Έργου |  |
| Γενικός Μελετητής(Ειδικός Συγκοινωνιολόγος) |  |
| Μελετήτής Οικονομολόγος |  |
| Δνση Χωροταξίας ΥΠΕΧΩΔΕ ή ΓΓ Περίφέρειας |  |
| ΥΠΕΧΩΔΕ |  |
| Ηλεκτρολόγος-Μηχανολόγος |  |
| Συναρμόδιες Υπηρεσίες |  |
| ΓΕΜ |  |
| ΕΥΠΕ / ΥΠΕΧΩΔΕ ή ΔΙΠΕΧΩ ΓΓ Περιφέρειας |  |
| Συναρμόδιοι Υπουργοί |  |
| Συναρμόδια Υπουργεία |  |

## Schedule

| ID | WBS | Task | Type | Duration | Start | Finish | Predecessors | Baseline start | Baseline finish | Baseline duration | Total slack | Free slack | Resources | Work | Text1 |
| --- | --- | --- | --- | --- | --- | --- | --- | --- | --- | --- | --- | --- | --- | --- | --- |
| 1 | 1 | **Διαδικασία Επιλογής Μελετητή** |  | 180d | 2002-01-01 | 2002-06-30 |  | 2002-01-11 | 2002-01-11 | 0.33d? | 0d |  | Εργοδότης | 10464h | 6Μ |
| 2 | 1.1 | Δημοσίευση Προκήρυξης Μελέτης |  | 45d | 2002-01-01 | 2002-02-15 |  | 2002-01-11 | 2002-01-11 | 0.33d? | 0d |  | Εργοδότης | 1080h | 1.5Μ |
| 3 | 1.2 | Αξιολόγηση Υποψήφιων Μελετητών |  | 28d | 2002-02-15 | 2002-03-15 | 2 | 2002-02-10 | 2002-03-12 | 30d | 0d |  | Εργοδότης | 672h | 1Μ |
| 4 | 1.3 | Επιλογή Μελετητή |  | 16d | 2002-03-15 | 2002-03-31 | 3 | 2002-03-12 | 2002-03-27 | 15d | 0d |  | Εργοδότης | 384h | 0.5Μ |
| 5 | 1.4 | Κοινοποίηση Απόφασης Ανάθεσης |  | 15d | 2002-03-31 | 2002-04-15 | 4 | 2002-03-27 | 2002-04-11 | 15d | 0d |  | Εργοδότης | 360h | 0.5Μ |
| 6 | 1.5 | Διαδικασία Ενστάσεων |  | 76d | 2002-04-15 | 2002-06-30 | 5 | 2002-04-11 | 2002-06-30 | 80d | 0d |  | Εργοδότης; ΓΕΜ | 3648h | 2.5Μ |
| 7 | 1.6 | Ανάθεση Μελέτης | milestone | 0d | 2002-06-30 | 2002-06-30 | 6 | 2002-06-30 | 2002-06-30 | 0d? | 0d |  | Εργοδότης |  | 0Μ |
| 8 | 2 | Κατάρτιση Σύμβασης - Υπογραφή Σύμβασης - Εγκατάσταση Αναδόχου |  | 31d | 2002-06-30 | 2002-07-31 | 7 | 2002-06-30 | 2002-07-31 | 31d | 0d |  | Εργοδότης; Προιστάμενη Αρχή; Διευθύνουσα Υπηρεσία; Γενικός Μελετητής | 2976h | 1Μ |
| 9 | 3 | Επίβλεψη Μελέτης |  | 915d | 2002-07-31 | 2005-01-31 | 8 | 2002-07-31 | 2005-05-31 | 1035d | 0d |  | Διευθύνουσα Υπηρεσία; Γενικός Μελετητής | 43920h | 30M |
| 10 | 4 | Εποπτεία Μελέτης |  | 915d | 2002-07-31 | 2005-01-31 | 9SS | 2002-07-31 | 2005-05-31 | 1035d | 0d |  | Προιστάμενη Αρχή; Γενικός Μελετητής | 43920h | 30M |
| 11 | 5 | **ΣΤΑΔΙΟ Ι: Αναγνωριστική μελέτη έργου / Προμελέτη Περιβαλλοντικών Επιπτώσεων** |  | 184d | 2002-07-31 | 2003-01-31 | 10SS | 2002-07-31 | 2003-03-01 | 213d | 0d |  |  | 23032h | 7Μ |
| 12 | 5.1 | Κυκλοφοριακή μελέτη / Θέσεις κόμβων |  | 61d | 2002-07-31 | 2002-09-30 |  | 2002-07-31 | 2002-09-29 | 2mo | 0d |  | Εργοδότης; Γενικός Μελετητής(Ειδικός Συγκοινωνιολόγος) | 2928h | 2Μ |
| 13 | 5.2 | **Αναγνώριση Έργου** |  | 138d | 2002-07-31 | 2002-12-16 | 12SS | 2002-09-29 | 2003-01-30 | 123d | 0d |  |  | 6984h | 4.5Μ |
| 14 | 5.2.1 | Αναγνώριση Έργου - Συγκέντρωση Στοιχείων |  | 31d | 2002-07-31 | 2002-08-31 |  | 2002-09-29 | 2002-10-30 | 31d | 0d |  | Διευθύνουσα Υπηρεσία; Μελετητές; Αλλοι τοπικοί φορείς | 2232h | 1Μ |
| 15 | 5.2.2 | Πρόγραμμα Τοπογραφικών Εργασίων |  | 30d | 2002-08-31 | 2002-09-30 | 14 | 2002-10-30 | 2002-11-14 | 15d | 0d |  | Διευθύνουσα Υπηρεσία; Γενικός Μελετητής | 1440h | 1Μ |
| 16 | 5.2.3 | Έγκριση Προγράμματος Τοπογραφικών Εργασίων |  | 16d | 2002-09-30 | 2002-10-16 | 15 | 2002-11-14 | 2002-11-30 | 16d | 1d | 0d | Εργοδότης | 384h | 0.5Μ |
| 17 | 5.2.4 | Εκπόνηση Προκαταρκτικών Εργασιών |  | 61d | 2002-10-16 | 2002-12-16 | 16 | 2002-11-30 | 2003-01-30 | 61d | 1d |  | Διευθύνουσα Υπηρεσία; Μελετητές | 2928h | 2Μ |
| 18 | 5.3 | Γεωλογική Αναγνώριση |  | 61d | 2002-10-16 | 2002-12-16 | 16, 13FS-61d | 2002-11-30 | 2003-01-30 | 61d | 1d | 0d | Διευθύνουσα Υπηρεσία; Γενικός Μελετητής; Γεωλόγος | 4392h | 2Μ |
| 19 | 5.4 | Εκπόνηση Οικονομοτεχνικής Μελέτης |  | 61d | 2002-10-16 | 2002-12-16 | 18FS-61d | 2002-11-30 | 2003-01-30 | 61d | 1d | 0d | Διευθύνουσα Υπηρεσία; Γενικός Μελετητής; Μελετήτής Οικονομολόγος | 4392h | 2Μ |
| 20 | 5.5 | Εκπόνηση Προμελέτης Περιβαλλοντικών Επιπτώσεων (Φ.Π.Χ. ή Απαλλαγή) - Υποβολή |  | 76d | 2002-10-16 | 2002-12-31 | 19SS | 2003-01-14 | 2003-03-01 | 46d | 1d | 0d | Διευθύνουσα Υπηρεσία; Γενικός Μελετητής | 3648h | 2.5Μ ή 1/6Μ |
| 21 | 5.6 | **Έγκριση Προμελέτης Περιβαλλοντικών Επιπτώσεων - Π.Π.Ε. (Π.Χ.)** |  | 31d | 2002-12-31 | 2003-01-31 | 20 | 2003-03-01 | 2003-03-31 | 30d | 1d |  |  | 688h | 1Μ |
| 22 | 5.6.1 | Παραλαβή Π.Π.Ε. (Φ.Π.Χ.) - Έλεγχος - Υποβολή |  | 8d | 2002-12-31 | 2003-01-08 |  | 2003-03-01 | 2003-03-04 | 3d | 1d | 0d | Διευθύνουσα Υπηρεσία | 192h | 0.25Μ |
| 23 | 5.6.2 | Παραλαβή Π.Π.Ε. (Φ.Π.Χ.) - Γνωμοδοτήσεις Συναρμοδιών |  | 15d | 2003-01-08 | 2003-01-23 | 22 | 2003-03-04 | 2003-03-07 | 3d | 1d | 0d | Συναρμόδιες Υπηρεσίες; ΕΥΠΕ / ΥΠΕΧΩΔΕ ή ΔΙΠΕΧΩ ΓΓ Περιφέρειας | 448h | 0.5Μ |
| 24 | 5.6.3 | Έκδοση Προκαταρκτικής Περιβαλλοντικής Εκτίμησης και Αξιολόγησης (Π. Χ.) |  | 8d | 2003-01-23 | 2003-01-31 | 23 | 2003-03-25 | 2003-03-31 | 6d | 1d | 0d | ΕΥΠΕ / ΥΠΕΧΩΔΕ ή ΔΙΠΕΧΩ ΓΓ Περιφέρειας | 48h | 0.25Μ |
| 25 | 6 | Έγκριση Σταδίου Ι |  | 28d | 2003-01-31 | 2003-02-28 | 24 | 2003-03-31 | 2003-04-30 | 30d | 1d | 0d | Εργοδότης | 672h | 1Μ |

| ID | WBS | Task | Type | Duration | Start | Finish | Predecessors | Baseline start | Baseline finish | Baseline duration | Total slack | Free slack | Resources | Work | Text1 |
| --- | --- | --- | --- | --- | --- | --- | --- | --- | --- | --- | --- | --- | --- | --- | --- |
| 26 | 7 | **ΣΤΑΔΙΟ ΙΙ: Προμελέτες Έργων / ΜΠΕ** |  | 351d | 2003-02-28 | 2004-02-14 | 25 | 2003-04-30 | 2004-03-31 | 336d | 1d |  |  | 47000h | 11Μ |
| 27 | 7.1 | Εντολή Έναρξης Σταδίου ΙΙ | milestone | 0d | 2003-02-28 | 2003-02-28 |  | 2003-04-30 | 2003-04-30 | 0d? | 703d |  | Εργοδότης |  | 0Μ |
| 28 | 7.2 | Εκτέλεση Τοπογραφικών Εργασιών |  | 76d | 2003-02-28 | 2003-05-15 | 16 | 2003-04-30 | 2003-07-14 | 75d | 1d | 0d | Διευθύνουσα Υπηρεσία; Γενικός Μελετητής; Τοπογράφος | 5472h | 2.5Μ |
| 29 | 7.3 | Προμελέτη Κυκλοφοριακού Έργου |  | 138d | 2003-05-15 | 2003-09-30 | 28 | 2003-07-14 | 2003-11-26 | 135d | 1d | 0d | Διευθύνουσα Υπηρεσία; Γενικός Μελετητής | 6624h | 4.5Μ |
| 30 | 7.4 | Προμελέτη Αποχέτευσης - Αποστράγγισης |  | 91d | 2003-06-30 | 2003-09-29 | 29SS+46d | 2003-08-28 | 2003-11-26 | 90d | 490d | 0d | Γενικός Μελετητής; Διευθύνουσα Υπηρεσία | 4368h | 3Μ |
| 31 | 7.5 | Οριστική Γεωλογική Μελέτη |  | 91d | 2003-06-30 | 2003-09-29 | 30SS | 2003-08-28 | 2003-11-26 | 90d | 490d | 0d | Διευθύνουσα Υπηρεσία; Γενικός Μελετητής; Γεωλόγος; Γεωτεχνικός | 8736h | 3Μ |
| 32 | 7.6 | Πρόγραμμα Γεωτεχνικών και Λοιπών Ερευνών |  | 30d | 2003-08-30 | 2003-09-29 | 31FF | 2003-10-27 | 2003-11-26 | 30d | 490d |  | Διευθύνουσα Υπηρεσία; Γενικός Μελετητής | 1440h | 1Μ |
| 33 | 7.7 | Προκαταρκτική Μελέτη Κόμβων και Παράπλευρων Έργων |  | 92d | 2003-06-30 | 2003-09-30 | 29SS+46d | 2003-08-28 | 2003-11-26 | 90d | 1d | 0d | Διευθύνουσα Υπηρεσία; Γενικός Μελετητής; Κυκλοφοριολόγος | 6624h | 3Μ |
| 34 | 7.8 | Προκαταρκτική Επεξεργασία Τεχνικών Έργων |  | 92d | 2003-06-30 | 2003-09-30 | 33SS | 2003-08-28 | 2003-11-26 | 90d | 366d | 0d | Διευθύνουσα Υπηρεσία; Γενικός Μελετητής | 4416h | 3Μ |
| 35 | 7.9 | Εκπόνηση Μελέτης Περιβαλλοντικών Επιπτώσεων |  | 92d | 2003-06-30 | 2003-09-30 | 34SS | 2003-08-28 | 2003-11-26 | 90d | 366d | 0d | Διευθύνουσα Υπηρεσία; Γενικός Μελετητής; Μελετητης Περιβαλλοντολόγος | 6624h | 3Μ |
| 36 | 7.10 | **Έγκριση Μελέτης Περιβαλλοντικών Επιπτώσεων-Μ.Π.Ε.** |  | 137d | 2003-09-30 | 2004-02-14 | 35 | 2003-11-26 | 2004-03-31 | 126d | 352d |  |  | 2696h | 4.5Μ |
| 37 | 7.10.1 | Παραλάβή Μ.Π.Ε.- Έλεγχος-Υποβολή |  | 15d | 2003-09-30 | 2003-10-15 |  | 2003-11-26 | 2003-12-11 | 15d | 366d | 0d | Διευθύνουσα Υπηρεσία | 360h | 0.5Μ |
| 38 | 7.10.2 | Παραλαβή Μ.Π.Ε.-Έλεγχος-Διαβίβαση |  | 15d | 2003-10-15 | 2003-10-30 | 37 | 2003-12-11 | 2004-01-10 | 30d | 364d | 0d | ΕΥΠΕ / ΥΠΕΧΩΔΕ ή ΔΙΠΕΧΩ ΓΓ Περιφέρειας | 88h | 0.5Μ |
| 39 | 7.10.3 | Παραλαβή Μ.Π.Ε.-Γνωμοδότηση-Διαβίβαση |  | 15d | 2003-10-30 | 2003-11-14 | 38 | 2003-12-26 | 2004-01-10 | 15d | 442d |  | Συναρμόδια Υπουργεία | 88h | 0.5Μ |
| 40 | 7.10.4 | Νομαρχιακό Συμβούλιο: Παραλαβή-Δημοσίευση Ανάρτηση ΜΠΕ |  | 15d | 2003-10-30 | 2003-11-14 | 38 | 2004-01-10 | 2004-02-09 | 30d | 366d | 0d | Νομαρχιακό Συμβούλιο | 360h | 0.5Μ |
| 41 | 7.10.5 | Διατύπωση Απόψεων - Αντιρρήσεων - Προτάσεων |  | 15d | 2003-11-14 | 2003-11-29 | 40 | 2004-01-25 | 2004-02-14 | 20d | 350d | 0d | Ενδιαφερόμενο Κοινό | 360h | 0.5Μ |
| 42 | 7.10.6 | Νομαρχιακό Συμβούλιο: Κριτική Άποψη Διαβίβαση |  | 15d | 2003-11-29 | 2003-12-14 | 41 | 2004-02-14 | 2004-02-29 | 15d | 350d | 0d | Νομαρχιακό Συμβούλιο | 360h | 0.5Μ |
| 43 | 7.10.7 | Σύνταξη Σχεδίου Απόφασης Έγκρισης περιβαλλοντικών όρων |  | 31d | 2003-12-14 | 2004-01-14 | 42 | 2004-02-29 | 2004-03-15 | 15d | 350d | 0d | ΕΥΠΕ / ΥΠΕΧΩΔΕ ή ΔΙΠΕΧΩ ΓΓ Περιφέρειας | 176h | 1Μ |
| 44 | 7.10.8 | Υπογραφή Υπουργών η Γ.Γ. Περιφέρειας |  | 15d | 2004-01-14 | 2004-01-29 | 43 | 2004-03-15 | 2004-03-31 | 16d | 350d | 0d | ΥΠΕΧΩΔΕ; ΓΓ Περίφέρειας; Συναρμόδιοι Υπουργοί | 808h | 0.5Μ |
| 45 | 7.10.9 | Έκδοση Απόφασης Έγκρισης Περιβαλλοντικών Όρων |  | 16d | 2004-01-29 | 2004-02-14 | 44 | 2004-03-31 | 2004-03-31 | 16d | 350d |  | ΕΥΠΕ / ΥΠΕΧΩΔΕ ή ΔΙΠΕΧΩ ΓΓ Περιφέρειας | 96h | 0.5Μ |
| 46 | 8 | ¨Εγκριση Σταδίου ΙΙ |  | 31d | 2003-09-30 | 2003-10-31 | 33 | 2004-02-29 | 2004-03-31 | 31d | 1d | 0d | Εργοδότης | 744h | 1Μ |
| 47 | 9 | **ΣΤΑΔΙΟ ΙΙΙ: Οριστικές Μελέτες Έργων** |  | 182d | 2003-10-31 | 2004-04-30 | 46 | 2004-03-31 | 2004-09-30 | 183d | 1d | 0d |  | 55584h | 6Μ |
| 48 | 9.1 | Εντολή Εναρξης Σταδίου ΙΙΙ | milestone | 0d | 2003-10-31 | 2003-10-31 |  | 2004-03-31 | 2004-03-31 | 0d? | 1d | 0d | Εργοδότης |  | 0Μ |
| 49 | 9.2 | Οριστική Μελέτη Κυκλοφοριακού Έργου |  | 182d | 2003-10-31 | 2004-04-30 | 48 | 2004-03-31 | 2004-09-30 | 183d | 1d | 0d | Διευθύνουσα Υπηρεσία; Γενικός Μελετητής | 8736h | 6Μ |
| 50 | 9.3 | Οριστική Μελέτη Αποχέτευσης - Αποστράγγισης |  | 122d | 2003-12-30 | 2004-04-30 | 49SS+60d | 2004-05-31 | 2004-09-28 | 120d | 1d |  | Διευθύνουσα Υπηρεσία; Γενικός Μελετητής | 5856h | 4Μ |
| 51 | 9.4 | Εκτέλεση Γεωτεχνικών και Λοιπών Ερευνών |  | 122d | 2003-10-31 | 2004-03-01 |  | 2004-03-31 | 2004-07-31 | 122d | 1d | 0d | Διευθύνουσα Υπηρεσία; Εδαφοτεχνικός Μελετητης | 5856h | 4Μ |
| 52 | 9.5 | Μελέτη Σήμανσης/ Ασφάλισης |  | 122d | 2003-10-31 | 2004-03-01 | 48 | 2004-03-31 | 2004-07-29 | 120d | 1d | 0d | Διευθύνουσα Υπηρεσία; Συγκοινωνιλόγος Μηχανικός | 5856h | 4Μ |
| 53 | 9.6 | Εξοπλισμός Οδού |  | 122d | 2003-12-30 | 2004-04-30 | 52SS+60d | 2004-05-31 | 2004-09-28 | 120d | 1d |  | Διευθύνουσα Υπηρεσία; Γενικός Μελετητής; Ηλεκτρολόγος-Μηχανολόγος | 8784h | 4Μ |
| 54 | 9.7 | Προμελέτη Κόμβων και Παράπλευρων Έργων |  | 122d | 2003-12-30 | 2004-04-30 | 49SS+60d | 2004-05-31 | 2004-09-28 | 120d | 1d |  | Διευθύνουσα Υπηρεσία; Γενικός Μελετητής; Κυκλοφοριολόγος | 8784h | 4Μ |
| 55 | 9.8 | Γεωτεχνικά Τεχνικών Έργων |  | 122d | 2003-12-30 | 2004-04-30 | 51SS+60d | 2004-05-31 | 2004-09-28 | 120d | 1d | 0d | Διευθύνουσα Υπηρεσία; Εδαφοτεχνικός Μελετητης | 5856h | 4Μ |
| 56 | 9.9 | Προμελέτη Τεχνικών Εργών |  | 122d | 2003-12-30 | 2004-04-30 | 55SS | 2004-05-31 | 2004-09-28 | 120d | 1d |  | Διευθύνουσα Υπηρεσία; Γενικός Μελετητής | 5856h | 4Μ |
| 57 | 10 | Εγκριση Σταδίου ΙΙΙ |  | 31d | 2004-04-30 | 2004-05-31 | 47 | 2004-09-30 | 2004-10-31 | 31d | 1d | 0d | Εργοδότης | 744h | 1Μ |

| ID | WBS | Task | Type | Duration | Start | Finish | Predecessors | Baseline start | Baseline finish | Baseline duration | Total slack | Free slack | Resources | Work | Text1 |
| --- | --- | --- | --- | --- | --- | --- | --- | --- | --- | --- | --- | --- | --- | --- | --- |
| 58 | 11 | **ΣΤΑΔΙΟ ΙV: Οριστικές Μελέτες Λοιπών Έργων** |  | 91d | 2004-05-31 | 2004-08-30 | 57 | 2004-10-31 | 2005-01-31 | 92d | 1d |  |  | 8736h | 2Μ |
| 59 | 11.1 | Εντολή Εναρξης Σταδίου IV | milestone | 0d | 2004-05-31 | 2004-05-31 |  | 2004-10-31 | 2004-10-31 | 0d? | 1d | 0d | Εργοδότης |  | 0Μ |
| 60 | 11.2 | Οριστική Μελέτη Κόμβων και Παράπλευρων Έργων |  | 91d | 2004-05-31 | 2004-08-30 | 59 | 2004-10-31 | 2005-01-31 | 92d | 1d | 0d | Διευθύνουσα Υπηρεσία; Γενικός Μελετητής | 4368h | 3Μ |
| 61 | 11.3 | Οριστική Μελέτη Τεχνικών Έργων |  | 91d | 2004-05-31 | 2004-08-30 | 60SS | 2004-10-31 | 2005-01-31 | 92d | 1d | 0d | Διευθύνουσα Υπηρεσία; Γενικός Μελετητής | 4368h | 3Μ |
| 62 | 12 | Εγκριση Σταδίου ΙV |  | 31d | 2004-08-30 | 2004-09-30 | 60, 61 | 2005-01-31 | 2005-03-02 | 30d | 1d | 0d | Εργοδότης | 744h | 1Μ |
| 63 | 13 | **ΣΤΑΔΙΟ V: Λοιπές Μελέτες** |  | 884d | 2002-08-31 | 2005-01-31 |  | 2004-10-31 | 2005-04-30 | 181d | 0d |  |  | 68064h | 6Μ |
| 64 | 13.1 | Κτηματολόγιο |  | 884d | 2002-08-31 | 2005-01-31 | 15SS, 61SS-123d | 2004-10-31 | 2005-04-30 | 181d | 0d |  | Διευθύνουσα Υπηρεσία; Γενικός Μελετητής; Τοπογράφος | 63648h | 4Μ |
| 65 | 13.2 | Μελέτες Εφαρμογής |  | 92d | 2004-09-30 | 2004-12-31 | 62, 64SS | 2004-10-31 | 2005-04-30 | 181d | 1d | 0d | Διευθύνουσα Υπηρεσία; Γενικός Μελετητής | 4416h | 3Μ |
| 66 | 14 | Εγκριση Σταδίου V |  | 30d | 2004-12-31 | 2005-01-30 | 65 | 2005-04-30 | 2005-05-31 | 31d | 1d |  | Εργοδότης | 720h | 1Μ |
| 67 | 15 | Απαλλοτριώσεις |  | 884d | 2002-08-31 | 2005-01-31 | 64SS, 65SS | 2004-10-31 | 2005-05-31 | 212d | 0d |  |  |  | 7Μ |
| 68 | 16 | Σύνταξη Τευχών Δημοπράτησης |  | 61d | 2004-11-30 | 2005-01-30 | 62FS+61d, 61 | 2005-01-31 | 2005-03-31 | 59d | 1d |  | Διευθύνουσα Υπηρεσία; Γενικός Μελετητής | 2928h | 2Μ |
